# ControlsSystems_v05_FSD_only

Schedule from MS Project, 2010-06-21 to 2012-04-20, costs in $.
CARA

## Calendars

- Standard: Mon-Fri 08:00-12:00, 13:00-17:00; Sat-Sun off.

## Resources

| Resource | Rate |
| --- | --- |
| EE |  |
| SW MC |  |
| SW AO |  |
| ET |  |
| Motion Device | 2000 |
| SW |  |
| Sun Storage 7210 | 40000 |
| Digital I/O | 100 |
| Analog I/O | 100 |
| Serial Comm | 125 |
| Temp Sensor | 200 |
| Power Control | 150 |
| Video | 500 |
| Ethernet | 100 |
| Time Sync | 50 |
| Server Computers | 7500 |
| Ethernet Switches | 5000 |

## Schedule

| ID | WBS | Task | Type | Duration | Start | Finish | Total slack | Resources | Work | Cost | Text1 |
| --- | --- | --- | --- | --- | --- | --- | --- | --- | --- | --- | --- |
| 1 | 1 | **Full Scale Development Phase** |  | 480d? | 2010-06-21 | 2012-04-20 | 0d |  | 7680h | 256,525 |  |
| 2 | 1.1 | **Milestones** |  | 480d? | 2010-06-21 | 2012-04-20 | 0d |  |  |  |  |
| 3 | 1.1.1 | End-of-FSD |  | 24mo | 2010-06-21 | 2012-04-20 | 0d |  |  |  |  |
| 4 | 1.1.2 | Midterm Review | milestone | 1d? | 2010-06-21 | 2010-06-21 | 479d |  |  |  |  |
| 5 | 1.2 | **Controls** |  | 60d? | 2010-06-21 | 2010-09-10 | 420d |  | 7680h | 256,525 |  |
| 6 | 1.2.1 | **AO Control System** |  | 40d? | 2010-06-21 | 2010-08-13 | 440d |  | 3180h | 117,975 |  |
| 7 | 1.2.1.1 | **Calibration / Simulation** |  | 15d | 2010-06-21 | 2010-07-09 | 465d |  | 320h | 22,300 | CALSIM |
| 8 | 1.2.1.1.1 | CALSIM Electronics |  | 3w | 2010-06-21 | 2010-07-09 | 465d | EE; Motion Device [1100%]; Analog I/O [200%]; Digital I/O | 120h | 22,300 |  |
| 9 | 1.2.1.1.2 | CALSIM Software |  | 3w | 2010-06-21 | 2010-07-09 | 465d | SW MC; SW AO | 200h |  |  |
| 10 | 1.2.1.2 | **Wide Field Relay (Low Order)** |  | 15d | 2010-06-21 | 2010-07-09 | 465d |  | 140h | 2,400 | WFR |
| 11 | 1.2.1.2.1 | WFR Electronics |  | 1w | 2010-06-21 | 2010-07-09 | 465d | EE; Motion Device; Analog I/O; Power Control [200%] | 40h | 2,400 |  |
| 12 | 1.2.1.2.2 | WFR Software |  | 1.33w | 2010-06-21 | 2010-06-29 | 473.33d | SW MC; SW AO [150%] | 100h |  |  |
| 13 | 1.2.1.3 | **LGS Wavefront Sensors** |  | 30d | 2010-06-21 | 2010-07-30 | 450d |  | 360h | 28,700 | LGSWFS |
| 14 | 1.2.1.3.1 | LGWFS Electronics |  | 3w | 2010-06-21 | 2010-07-30 | 450d | EE; Motion Device [1300%]; Analog I/O; Power Control [800%]; Temp Sensor [700%] | 120h | 28,700 |  |
| 15 | 1.2.1.3.2 | LGSWFS Software |  | 4w | 2010-06-21 | 2010-07-16 | 460d | SW MC; SW AO | 240h |  |  |
| 16 | 1.2.1.4 | **Acquisition Camera** |  | 10d | 2010-06-21 | 2010-07-02 | 470d |  | 140h | 4,250 | ACQ |
| 17 | 1.2.1.4.1 | ACQ Electronics |  | 1w | 2010-06-21 | 2010-07-02 | 470d | EE; Motion Device [200%]; Analog I/O; Power Control | 40h | 4,250 |  |
| 18 | 1.2.1.4.2 | ACQ Software |  | 2w | 2010-06-21 | 2010-07-02 | 470d | SW MC; SW AO | 100h |  |  |
| 19 | 1.2.1.5 | **Low Order Wavefront Sensors** |  | 15d | 2010-06-21 | 2010-07-09 | 465d |  | 240h | 20,725 | LOWFS |
| 20 | 1.2.1.5.1 | LOWFS Electronics |  | 2w | 2010-06-21 | 2010-07-09 | 465d | EE; Motion Device [900%]; Analog I/O [300%]; Power Control [1000%]; Temp Sensor [400%]; Serial Comm | 80h | 20,725 |  |
| 21 | 1.2.1.5.2 | LOWFS Software |  | 3w | 2010-06-21 | 2010-07-09 | 465d | SW MC; SW AO | 160h |  |  |
| 22 | 1.2.1.6 | **Narrow Field Relay (High Order)** |  | 10d | 2010-06-21 | 2010-07-02 | 470d |  | 140h | 4,400 | NFR |
| 23 | 1.2.1.6.1 | NFR Electronics |  | 1w | 2010-06-21 | 2010-07-02 | 470d | EE; Motion Device [200%]; Power Control [200%]; Analog I/O | 40h | 4,400 |  |
| 24 | 1.2.1.6.2 | NFR Software |  | 1.5w | 2010-06-21 | 2010-06-30 | 472.5d | SW MC; SW AO | 100h |  |  |

Notes:
- 7: Hardware: / ·injection fold (linear) / ·field selector (linear) / ·source grid (4dof: 3xlinear,1xrotator) / ·source positioner (rotator) / ·laser source (linear) / ·turbulence generator (3dof: 2xrotator, 1xlinear) / Software: / ·single dof device controllers for: fold, selector, positioner, laser / ·special device controller for source grid / ·special device controller for turbulence generator / ·non-motion device controls for laser source and / ·non-motion device controls for turblence generator / ·supervisory control sequencer (~14 calibration sequences)
- 10: First optical relay of the NGAO AO system as the light leaves the telescope tertiary mirror. It contains the Low Order Deformable Mirror (LODM), various pickoff optics and optics for reimage the main telescope Nasmyth focus. This term is preferred to Low Order Relay or Woofer Relay. / PBS refers to this as: "Low Order DM & Tip-Tilt Platform" but we're going to use "Wide Field Relay" (per Chris' definition) even though we prefer "Low Order Relay". / Hardware: / ·image rotator* / ·lodm t/t (non-realtime) / ·lodm (non-realtime) / Software: / ·image rotator device control / ·lodm non-realtime controls: on/off / ·image rotator high level controller
- 13: Hardware: / ·3x object select (2dof) / ·7x tip/tilt (non-realtime) / ·3x patrolling beacon (2dof) / ·focus stage / ·details for handling pickoff arms / Software: / ·device controllers for 6x2dof devices / ·device controller for linear focus stage / ·non-realtime control for 7 t/t devices (on/off) / ·supervisory controller: moving more of the intelligence for the pickoffs to the NGAO Controls level to get the best control of positioning. also need some extra time to investigate and design spiral searches and the numerous control loops
- 16: Hardware: / ·filter wheel (rotary) / ·focus stage (linear) / Software: / ·device controller for filter wheel / ·device controller for focus stage / ·supervisory conrol sequencer
- 19: Detailed design and documentation for: / Hardware: / ·3x object select arm (2dof: rotatary) / ·3x tip/tilt non-realtime control / ·lowfs dm non-realtime control / ·3x focus stage (linear) / Software: / ·customized device controller for object select arms / ·non-motion device control (on/off) for 3x tip/tilt and 1x dm stages / ·3x device controller for linear focus stage / ·supervisory sequencer
- 22: Second optical relay of the NGAO AO system as the light leaves the telescope tertiary mirror. It follows directly after the Wide Field Relay. It contains the High Order Deformable Mirror (HODM) pickoff optics and optics for reimage the main telescope Nasmyth focus. This term is preferred to High Order Relay or Tweeter Relay. / PBS refers to this as: "High Order DM & Tip-Tilt Platform" but we're going to use "Narrow Field Relay" (per Chris' definition) even though we prefer "High Order Relay". / Hardware: / ·hodm slow tip/tilt (2dof) / ·hodm non-realtime control / Software: / ·hodm non-realtime control / ·device controller for tip/tilt / ·tip/tilt sequencer controller

| ID | WBS | Task | Duration | Start | Finish | Total slack | Resources | Work | Cost | Text1 |
| --- | --- | --- | --- | --- | --- | --- | --- | --- | --- | --- |
| 25 | 1.2.1.7 | **Optical Switchyard** | 15d | 2010-06-21 | 2010-07-09 | 465d |  | 60h | 8,000 | AOSY |
| 26 | 1.2.1.7.1 | AOSY Electronics | 1w | 2010-06-21 | 2010-07-09 | 465d | EE; Motion Device [400%] | 40h | 8,000 |  |
| 27 | 1.2.1.7.2 | AOSY Software | 0.5w | 2010-06-21 | 2010-06-23 | 477.5d | SW MC | 20h |  |  |
| 28 | 1.2.1.8 | **NGS Wavefront Sensor** | 15d | 2010-06-21 | 2010-07-09 | 465d |  | 240h | 14,350 | NGSWFS |
| 29 | 1.2.1.8.1 | NGSWFS Electronics | 2w | 2010-06-21 | 2010-07-09 | 465d | EE; Motion Device [700%]; Temp Sensor; Power Control | 80h | 14,350 |  |
| 30 | 1.2.1.8.2 | NGSWFS Software | 3w | 2010-06-21 | 2010-07-09 | 465d | SW MC; SW AO | 160h |  |  |
| 31 | 1.2.1.9 | **Atmospheric Dispersion Corrector** | 10d | 2010-06-21 | 2010-07-02 | 470d |  | 180h | 6,000 | ADC |
| 32 | 1.2.1.9.1 | ADC Electronics | 2w | 2010-06-21 | 2010-07-02 | 470d | EE; Motion Device [300%] | 80h | 6,000 |  |
| 33 | 1.2.1.9.2 | ADC Software | 2w | 2010-06-21 | 2010-07-02 | 470d | SW MC; SW AO | 100h |  |  |
| 34 | 1.2.1.10 | **AO Enclosures** | 40d | 2010-06-21 | 2010-08-13 | 440d |  | 920h | 6,850 | ENC |
| 35 | 1.2.1.10.1 | **Electronics** | 40d | 2010-06-21 | 2010-08-13 | 440d |  | 760h | 6,850 |  |
| 36 | 1.2.1.10.1.1 | AO Room (inc: input and output hatches) | 2w | 2010-06-21 | 2010-07-02 | 470d | EE; ET; Temp Sensor [1000%]; Analog I/O [500%]; Video [200%]; Power Control; Digital I/O [500%] | 160h | 4,150 |  |
| 37 | 1.2.1.10.1.2 | AO Electronics Vault | 8w | 2010-06-21 | 2010-08-13 | 440d | EE; Analog I/O [400%] | 320h | 400 |  |
| 38 | 1.2.1.10.1.3 | AO Cold Enclosure (Bench) | 7w | 2010-06-21 | 2010-08-06 | 445d | EE; Temp Sensor [600%]; Analog I/O [300%]; Video; Digital I/O [300%] | 280h | 2,300 |  |
| 39 | 1.2.1.10.2 | ENC Software | 4w | 2010-06-21 | 2010-07-16 | 460d | SW MC | 160h |  |  |
| 40 | 1.2.1.11 | AO Control Sequencer | 8w | 2010-06-21 | 2010-08-13 | 440d | SW AO | 320h |  | AOSEQ |
| 41 | 1.2.1.12 | RTC Interface | 10d? | 2010-06-21 | 2010-07-02 | 470d | SW | 80h |  |  |
| 42 | 1.2.1.13 | Atmospheric Profiler Interface | 5d? | 2010-06-21 | 2010-06-25 | 475d | SW | 40h |  |  |
| 43 | 1.2.2 | **Laser Guide Star Facility Control System** | 40d? | 2010-06-21 | 2010-08-13 | 440d |  | 1600h | 58,575 |  |
| 44 | 1.2.2.1 | **Laser Controller Interface** | 10d? | 2010-06-21 | 2010-07-02 | 470d |  | 100h | 100 | LIF |
| 45 | 1.2.2.1.1 | LIF Communication Cabling | 2.5d? | 2010-06-21 | 2010-06-23 | 477.5d | EE; Ethernet | 20h | 100 |  |
| 46 | 1.2.2.1.2 | LIF Control / Status Interface | 10d? | 2010-06-21 | 2010-07-02 | 470d | SW MC | 80h |  |  |
| 47 | 1.2.2.2 | **Laser Switchyard** | 10d? | 2010-06-21 | 2010-07-02 | 470d |  | 200h | 20,400 | LSY |
| 48 | 1.2.2.2.1 | LSY Electronics | 10d? | 2010-06-21 | 2010-07-02 | 470d | EE; Motion Device [1000%]; Analog I/O; Ethernet [300%] | 80h | 20,400 |  |
| 49 | 1.2.2.2.2 | LSY Software | 10d? | 2010-06-21 | 2010-07-02 | 470d | SW MC; SW AO | 120h |  |  |

Notes:
- 25: Detailed design and documentation: / Hardware: / ·interferometer dichroic (linear) / ·acquisition fold (linear) [part of ACQ] / ·ngs wfs dichroic (linear) [part of NGSWFS] / ·instrument select (rotary) / Software: / ·3x linear device controllers / ·1x rotary device controller
- 28: Hardware: / ·2x wfs fsm (2dof: tip/tilt) / ·wfs lenslet (2dof: linear) / ·focus stage (linear) / ·collision avoidance mechanism between lenslet and focus stage / Software: / ·2dof device controllers for fsms and lenslet / ·device controller for focus stage / ·supervisory controller: there will have to be some serious thought about how to coordinate offloading / tip-tilt correction between TTM2 and FSMs. Based on Eds comment about focus and lenslet stage collision it seems like the supervisory controller will have to be more intelligent than I originally assumed.
- 31: Detailed design and documenation base on assumptions of what it is / Hardware: / ·adc (2dof: either rotary or linear) / ·linear stage / Software: / ·2dof device controller (custom?) / ·linear stage device controller / ·high level controller (actively controlling positions)
- 36: Large room on the Keck Telescope Nasmyth platform containing the AO system, for NGAO it will be climate controlled. Temperature will be ~dome ambient, nominally 0 degrees Celsius +/- 10 degrees. / ·room temperature / ·humidity / ·dust / ·rack/equipment temperatures / ·camera / ·A/C controls / ·HEPA controls / ·lights controls / ·input hatch* / ·interferometer output hatch*
- 37: Large room containing electronics that support operation of the AO system. Room is keep at a warmer temperature than the AO Room, ~17 degrees Celsius (63 degrees Fahrenheit). Waste heat is removed by a cooling system. The Electronics Vault must be thermally isolated to some degree from adjoining AO Room. Frequently abbreviated e-vault. / ·glycol flow / ·temperature / ·ca/sim source output / ·cal/sim source power / ·cal/sim source intensity readback / ·motion control local/remote / ·motion control status / ·ac controls / ·racks / ·cabling
- 38: Smaller enclosure that surrounds the AO system bench and is cooled to approximately -15 degree Celsius to reduce emissivity (background) for infrared wavelength observations. (Note that the exact temperature of the AO Cold Enclosure is subject to change as design progresses). Previously referred to as the cold box. / ·temperature / ·humidity / ·dust / ·video camera / ·accels / ·IF IBM-T source / ·lights control / ·racks / ·cabling
- 39: Software: / ·readback for: / ·temperature/ ·humidity/ ·dust/ ·cal/sim source intensity / ·control and readback for: / ·accels/ ·AC/ ·HEPA/ ·lights/ ·motion control/ ·cal/sim source / ·surveillance camera controls
- 40: High level AO control sequencer. / Interfaces to higher level operations level controllers and coordinates and controls lower level AO device controllers accordingly. Lots of sequences need to be understood and developed.
- 44: Detailed design and documentation for interfacing to the vendor supplied laser controller. / Will be reading statuses and sending commands to laser controller. No automated control loops are envisioned at this time.
- 47: Hardware: / ·3x polarizing 1/4 waveplate (1dof: rotary) / ·3x polarizing 1/2 waveplate (1dof: rotary) / ·3x pointing/steering mirrors (2dof: tip/tilt) / ·alignment beamsplitter (1dof: linear) / Software: / ·6x device controllers for rotary devices / ·3x 2dof device controllers for pointing/steering mirrors / ·linear device controller / ·supervisory sequencer

| ID | WBS | Task | Duration | Start | Finish | Total slack | Resources | Work | Cost | Text1 |
| --- | --- | --- | --- | --- | --- | --- | --- | --- | --- | --- |
| 50 | 1.2.2.3 | **Laser Beam Generation System** | 30d? | 2010-06-21 | 2010-07-30 | 450d |  | 520h | 34,350 | BGS |
| 51 | 1.2.2.3.1 | BGS Electronics | 20d? | 2010-06-21 | 2010-07-16 | 460d | EE; Video; Ethernet [200%]; Analog I/O [900%]; Power Control [500%]; Motion Device [1600%] | 160h | 34,350 |  |
| 52 | 1.2.2.3.2 | BGS Software | 30d? | 2010-06-21 | 2010-07-30 | 450d | SW MC; SW AO | 360h |  |  |
| 53 | 1.2.2.4 | **Laser Safety System** | 15d? | 2010-06-21 | 2010-07-09 | 465d |  | 240h | 225 | LSS |
| 54 | 1.2.2.4.1 | LSS Electronics | 1d? | 2010-06-21 | 2010-06-21 | 479d | Ethernet; Serial Comm |  | 225 |  |
| 55 | 1.2.2.4.2 | **LSS Software** | 15d? | 2010-06-21 | 2010-07-09 | 465d |  | 240h |  |  |
| 56 | 1.2.2.4.2.1 | Safety System Interface | 10d? | 2010-06-21 | 2010-07-02 | 470d | SW MC | 80h |  |  |
| 57 | 1.2.2.4.2.2 | LTCS | 15d? | 2010-06-21 | 2010-07-09 | 465d | SW AO | 120h |  |  |
| 58 | 1.2.2.4.2.3 | Laser Clearinghouse | 5d? | 2010-06-21 | 2010-06-25 | 475d | SW AO | 40h |  |  |
| 59 | 1.2.2.5 | **Laser Service Enclosure** | 15d? | 2010-06-21 | 2010-07-09 | 465d |  | 220h | 2,300 | LSE |
| 60 | 1.2.2.5.1 | LSE Electronics | 10d? | 2010-06-21 | 2010-07-09 | 465d | EE; ET; Temp Sensor [900%]; Video | 160h | 2,300 |  |
| 61 | 1.2.2.5.2 | LSE Software | 7.5d? | 2010-06-21 | 2010-06-30 | 472.5d | SW MC | 60h |  |  |
| 62 | 1.2.2.6 | Laser Beam Transport Optics | 1d? | 2010-06-21 | 2010-06-21 | 479d |  |  |  |  |
| 63 | 1.2.2.7 | Laser Launch Telescope Assembly | 1d? | 2010-06-21 | 2010-06-21 | 479d | Temp Sensor [600%] |  | 1,200 |  |
| 64 | 1.2.2.8 | Laser Control Sequencer | 40d? | 2010-06-21 | 2010-08-13 | 440d | SW AO | 320h |  |  |
| 65 | 1.2.3 | **Control System Infrastructure** | 60d? | 2010-06-21 | 2010-09-10 | 420d |  | 2900h | 79,975 |  |
| 66 | 1.2.3.1 | **Motion Control** | 40d? | 2010-06-21 | 2010-08-13 | 440d |  | 480h | 8,000 |  |
| 67 | 1.2.3.1.1 | MC Electronics | 10d? | 2010-06-21 | 2010-07-02 | 470d | EE; ET; Motion Device [400%] | 160h | 8,000 |  |
| 68 | 1.2.3.1.2 | MC Software | 40d? | 2010-06-21 | 2010-08-13 | 440d | SW MC | 320h |  |  |
| 69 | 1.2.3.2 | **Device Control** | 40d? | 2010-06-21 | 2010-08-13 | 440d |  | 640h | 1,850 |  |
| 70 | 1.2.3.2.1 | DC Electronics | 20d? | 2010-06-21 | 2010-07-16 | 460d | EE; ET; Digital I/O [200%]; Analog I/O [200%]; Serial Comm [200%]; Temp Sensor [200%]; Power Control [200%]; Video | 320h | 1,850 |  |
| 71 | 1.2.3.2.2 | DC Software | 40d? | 2010-06-21 | 2010-08-13 | 440d | SW MC | 320h |  |  |
| 72 | 1.2.3.3 | **Monitoring** | 1d? | 2010-06-21 | 2010-06-21 | 479d |  |  |  | MON |
| 73 | 1.2.3.3.1 | Vibration | 1d? | 2010-06-21 | 2010-06-21 | 479d |  |  |  |  |
| 74 | 1.2.3.3.2 | Temperature | 1d? | 2010-06-21 | 2010-06-21 | 479d |  |  |  |  |
| 75 | 1.2.3.3.3 | Humidity | 1d? | 2010-06-21 | 2010-06-21 | 479d |  |  |  |  |
| 76 | 1.2.3.3.4 | Dust | 1d? | 2010-06-21 | 2010-06-21 | 479d |  |  |  |  |

Notes:
- 50: Hardware: / ·2x beam splitter (1dof: linear) / ·imager pickoff (1dof: linear) / ·3x patrolling lgs steering (2dof: linear) / ·asterism rotator (1dof: rotary) / ·asterism tip/tilt (2dof: tipt/tilt) / ·fast shutter / ·focus stage (1dof: linear) / ·lto polarization sensor (2dof: rotary) / ·lto cover (1dof: ?) / ·beam wfs / ·power / ·polarization sensor / ·beam position sensor / ·AC controls / ·temperature / ·humidity / Software: / ·5x 1dof linear device controllers / ·3x 2dof linear device controllers / ·1dof rotary device controller / ·2dof rotary device controller / ·2dof tip/tilt device controller / ·shutter type device control / ·non-motion device status and control / ·high level control sequencer (5wks)
- 54: Don't think there's anything here for Ed to do... I'm assuming Jason will be responsible for installing and making this work under his WBS.
- 56: Detailed design and documenation for interfacing to laser safety system.
- 57: per JC: Need to make existing code work with 7beams and transfer to new system, see: / http://www.oir.caltech.edu/twiki_oir/pub/Keck/NGAO/LaserPDRPhase/NGAO_LTCS_Modification_Preliiminary_Design_DS.doc / DSummers estimate: DD 32hrs, FSD 100hrs / reference documents: / http://keckshare.keck.hawaii.edu/dsweb/Get/Document-35985/KAON713.doc/ http://keckshare.keck.hawaii.edu/dsweb/Get/Document-7474/SDF_KECK_LTCS_URLs.doc/ http://keckshare.keck.hawaii.edu/dsweb/Get/Document-7472/SDF_revised_draft.doc
- 58: per JC: Transfer existing tool to new system, see: http://www.oir.caltech.edu/twiki_oir/pub/Keck/NGAO/LaserPDRPhase/NGAO_Laser_Clearing_House_Planning.doc
- 59: Hardware: / ·beam dump / ·temperature / ·humidity / ·dust / ·video camera / ·AC controls / Software: / ·non-motion device status and controls
- 62: This is being handled by the MRI proposal and JC has it covered. / Device controls handled under BGS
- 63: No motion control just device controls / · temp sensor / ·humidity
- 64: Detailed design and documentation for high level laser control sequencer. / Interfaces to higher level operations level controllers and coordinates and controls lower level laser device controllers accordingly.
- 66: Motion device control. / Hardware: / ·platform selection / ·motion controller selection / ·motion controller locations / ·amplifiers / ·wiring / ·etc... / Software: / ·software interface / · low level device controller / ·device control state machine / · low level engineering gui interface
- 69: Non-motion device control. / Hardware: / ·controller selection / ·temperature / ·humidity / ·dust/ ·wiring / ·video camera / ·power / ·etc... / Software: / ·device drivers for each type / ·interface definition / ·attribute definitions / ·method definition / ·etc...
- 72: The bulk of this would be done under "Device Control" for hardware selection and software driver stuff. With the actual monitoring falling uder the various enclosures.

| ID | WBS | Task | Duration | Start | Finish | Total slack | Resources | Work | Cost | Text1 |
| --- | --- | --- | --- | --- | --- | --- | --- | --- | --- | --- |
| 77 | 1.2.3.4 | **Electronics** | 5d? | 2010-06-21 | 2010-06-25 | 475d |  | 180h | 30,125 |  |
| 78 | 1.2.3.4.1 | Instrument Interface | 5d? | 2010-06-21 | 2010-06-25 | 475d | EE; Ethernet [200%] | 40h | 200 |  |
| 79 | 1.2.3.4.2 | Interferometer Interface | 2.5d? | 2010-06-21 | 2010-06-23 | 477.5d | EE; Ethernet | 20h | 100 |  |
| 80 | 1.2.3.4.3 | Control Computers | 2.5d? | 2010-06-21 | 2010-06-23 | 477.5d | EE; Power Control [1000%]; Serial Comm [500%]; Ethernet [500%] | 20h | 2,625 |  |
| 81 | 1.2.3.4.4 | Realtime Control Computers | 5d? | 2010-06-21 | 2010-06-25 | 475d | EE; Power Control [700%]; Serial Comm [200%]; Time Sync | 40h | 1,350 |  |
| 82 | 1.2.3.4.5 | Time Infrastructure (Sync) | 5d? | 2010-06-21 | 2010-06-25 | 475d | EE; Time Sync [200%]; Power Control | 40h | 250 |  |
| 83 | 1.2.3.4.6 | Communication Infrastructure | 2.5d? | 2010-06-21 | 2010-06-23 | 477.5d | EE; Server Computers [200%]; Ethernet Switches [200%]; Power Control [400%] | 20h | 25,600 |  |
| 84 | 1.2.3.5 | **Software** | 50d? | 2010-06-21 | 2010-08-27 | 430d |  | 1080h |  | INFR |
| 85 | 1.2.3.5.1 | Health Monitoring | 10d? | 2010-06-21 | 2010-07-02 | 470d | SW | 80h |  |  |
| 86 | 1.2.3.5.2 | Logging | 10d? | 2010-06-21 | 2010-07-02 | 470d | SW | 80h |  |  |
| 87 | 1.2.3.5.3 | Archiving | 10d? | 2010-06-21 | 2010-07-02 | 470d | SW | 80h |  |  |
| 88 | 1.2.3.5.4 | Alarming | 15d? | 2010-06-21 | 2010-07-09 | 465d | SW | 120h |  |  |
| 89 | 1.2.3.5.5 | Configuration | 30d? | 2010-06-21 | 2010-07-30 | 450d | SW | 240h |  |  |
| 90 | 1.2.3.5.6 | Keyword Interface | 5d? | 2010-06-21 | 2010-06-25 | 475d | SW | 40h |  |  |
| 91 | 1.2.3.5.7 | EPICS Channel Access Interface | 5d? | 2010-06-21 | 2010-06-25 | 475d | SW | 40h |  |  |
| 92 | 1.2.3.5.8 | Utility Scripts | 50d? | 2010-06-21 | 2010-08-27 | 430d | SW | 400h |  |  |
| 93 | 1.2.3.6 | **Data Server** | 60d? | 2010-06-21 | 2010-09-10 | 420d |  | 520h | 40,000 | DS |
| 94 | 1.2.3.6.1 | DS Software | 60d? | 2010-06-21 | 2010-09-10 | 420d | SW | 480h |  |  |
| 95 | 1.2.3.6.2 | DS Hardware Setup | 5d? | 2010-06-21 | 2010-06-25 | 475d | SW; Sun Storage 7210 | 40h | 40,000 |  |

Notes:
- 89: ·config Server / ·database design / ·config snapshot / ·gui
- 92: Library of common functions / tasks for observers, SA, developers, etc... / Still needs to be defined but I stuck a number in for now.
- 93: Detailed design and documentation including recommended computer/disk hardware selection. / Computers: 1wk / Software: 12wks / ·database definition and design / ·log files definition and design / ·interface tool specs and design / ·inter-process comm spec and design
