# NGAO_Controls_FSD

Schedule from MS Project, 2010-06-21 to 2010-09-10, costs in $.
CARA

## Calendars

- Standard: Mon-Fri 08:00-12:00, 13:00-17:00; Sat-Sun off.

## Resources

| Resource | Rate |
| --- | --- |
| EE |  |
| SW MC |  |
| SW AO |  |
| ET |  |
| Motion Device | 2000 |
| Device | 500 |
| SW |  |
| Sun Storage 7210 | 40000 |

## Schedule

| ID | WBS | Task | Duration | Start | Finish | Total slack | Resources | Work | Cost | Text1 |
| --- | --- | --- | --- | --- | --- | --- | --- | --- | --- | --- |
| 1 | 1 | **Full Scale Development Phase** | 60d? | 2010-06-21 | 2010-09-10 | 0d |  | 7680h | 291,000 |  |
| 2 | 1.1 | **Controls** | 60d? | 2010-06-21 | 2010-09-10 | 0d |  | 7680h | 291,000 |  |
| 3 | 1.1.1 | **AO Control System** | 40d? | 2010-06-21 | 2010-08-13 | 20d |  | 3180h | 164,500 |  |
| 4 | 1.1.1.1 | **Calibration / Simulation** | 15d | 2010-06-21 | 2010-07-09 | 45d |  | 320h | 24,500 | CALSIM |
| 5 | 1.1.1.1.1 | Electronics | 3w | 2010-06-21 | 2010-07-09 | 45d | EE; Motion Device [1100%]; Device [500%] | 120h | 24,500 |  |
| 6 | 1.1.1.1.2 | Software | 3w | 2010-06-21 | 2010-07-09 | 45d | SW MC; SW AO | 200h |  |  |
| 7 | 1.1.1.2 | **Wide Field Relay (Low Order)** | 15d | 2010-06-21 | 2010-07-09 | 45d |  | 140h | 3,000 | WFR |
| 8 | 1.1.1.2.1 | Electronics | 1w | 2010-06-21 | 2010-07-09 | 45d | EE; Motion Device; Device [200%] | 40h | 3,000 |  |
| 9 | 1.1.1.2.2 | Software | 1.33w | 2010-06-21 | 2010-06-29 | 53.33d | SW MC; SW AO [150%] | 100h |  |  |
| 10 | 1.1.1.3 | **LGS Wavefront Sensors** | 30d | 2010-06-21 | 2010-07-30 | 30d |  | 360h | 29,000 | LGSWFS |
| 11 | 1.1.1.3.1 | Electronics | 3w | 2010-06-21 | 2010-07-30 | 30d | EE; Motion Device [1300%]; Device [600%] | 120h | 29,000 |  |
| 12 | 1.1.1.3.2 | Software | 4w | 2010-06-21 | 2010-07-16 | 40d | SW MC; SW AO | 240h |  |  |
| 13 | 1.1.1.4 | **Acquisition Camera** | 10d | 2010-06-21 | 2010-07-02 | 50d |  | 140h | 4,000 | ACQ |
| 14 | 1.1.1.4.1 | Electronics | 1w | 2010-06-21 | 2010-07-02 | 50d | EE; Motion Device [200%] | 40h | 4,000 |  |
| 15 | 1.1.1.4.2 | Software | 2w | 2010-06-21 | 2010-07-02 | 50d | SW MC; SW AO | 100h |  |  |
| 16 | 1.1.1.5 | **Low Order Wavefront Sensors** | 15d | 2010-06-21 | 2010-07-09 | 45d |  | 240h | 20,500 | LOWFS |
| 17 | 1.1.1.5.1 | Electronics | 2w | 2010-06-21 | 2010-07-09 | 45d | EE; Motion Device [900%]; Device [500%] | 80h | 20,500 |  |
| 18 | 1.1.1.5.2 | Software | 3w | 2010-06-21 | 2010-07-09 | 45d | SW MC; SW AO | 160h |  |  |
| 19 | 1.1.1.6 | **Narrow Field Relay (High Order)** | 10d | 2010-06-21 | 2010-07-02 | 50d |  | 140h | 6,000 | NFR |
| 20 | 1.1.1.6.1 | Electronics | 1w | 2010-06-21 | 2010-07-02 | 50d | EE; Motion Device [200%]; Device [400%] | 40h | 6,000 |  |
| 21 | 1.1.1.6.2 | Software | 1.5w | 2010-06-21 | 2010-06-30 | 52.5d | SW MC; SW AO | 100h |  |  |
| 22 | 1.1.1.7 | **Optical Switchyard** | 15d | 2010-06-21 | 2010-07-09 | 45d |  | 60h | 8,000 | AOSY |
| 23 | 1.1.1.7.1 | Electronics | 1w | 2010-06-21 | 2010-07-09 | 45d | EE; Motion Device [400%] | 40h | 8,000 |  |
| 24 | 1.1.1.7.2 | Software | 0.5w | 2010-06-21 | 2010-06-23 | 57.5d | SW MC | 20h |  |  |

Notes:
- 4: Hardware: / ·injection fold (linear) / ·field selector (linear) / ·source grid (4dof: 3xlinear,1xrotator) / ·source positioner (rotator) / ·laser source (linear) / ·turbulence generator (3dof: 2xrotator, 1xlinear) / Software: / ·single dof device controllers for: fold, selector, positioner, laser / ·special device controller for source grid / ·special device controller for turbulence generator / ·non-motion device controls for laser source and / ·non-motion device controls for turblence generator / ·supervisory control sequencer (~14 calibration sequences)
- 7: First optical relay of the NGAO AO system as the light leaves the telescope tertiary mirror. It contains the Low Order Deformable Mirror (LODM), various pickoff optics and optics for reimage the main telescope Nasmyth focus. This term is preferred to Low Order Relay or Woofer Relay. / PBS refers to this as: "Low Order DM & Tip-Tilt Platform" but we're going to use "Wide Field Relay" (per Chris' definition) even though we prefer "Low Order Relay". / Hardware: / ·image rotator* / ·lodm t/t (non-realtime) / ·lodm (non-realtime) / Software: / ·image rotator device control / ·lodm non-realtime controls: on/off / ·image rotator high level controller
- 10: Hardware: / ·3x object select (2dof) / ·7x tip/tilt (non-realtime) / ·3x patrolling beacon (2dof) / ·focus stage / ·details for handling pickoff arms / Software: / ·device controllers for 6x2dof devices / ·device controller for linear focus stage / ·non-realtime control for 7 t/t devices (on/off) / ·supervisory controller: moving more of the intelligence for the pickoffs to the NGAO Controls level to get the best control of positioning. also need some extra time to investigate and design spiral searches and the numerous control loops
- 13: Hardware: / ·filter wheel (rotary) / ·focus stage (linear) / Software: / ·device controller for filter wheel / ·device controller for focus stage / ·supervisory conrol sequencer
- 16: Detailed design and documentation for: / Hardware: / ·3x object select arm (2dof: rotatary) / ·3x tip/tilt non-realtime control / ·lowfs dm non-realtime control / ·3x focus stage (linear) / Software: / ·customized device controller for object select arms / ·non-motion device control (on/off) for 3x tip/tilt and 1x dm stages / ·3x device controller for linear focus stage / ·supervisory sequencer
- 19: Second optical relay of the NGAO AO system as the light leaves the telescope tertiary mirror. It follows directly after the Wide Field Relay. It contains the High Order Deformable Mirror (HODM) pickoff optics and optics for reimage the main telescope Nasmyth focus. This term is preferred to High Order Relay or Tweeter Relay. / PBS refers to this as: "High Order DM & Tip-Tilt Platform" but we're going to use "Narrow Field Relay" (per Chris' definition) even though we prefer "High Order Relay". / Hardware: / ·hodm slow tip/tilt (2dof) / ·hodm non-realtime control / Software: / ·hodm non-realtime control / ·device controller for tip/tilt / ·tip/tilt sequencer controller
- 22: Detailed design and documentation: / Hardware: / ·interferometer dichroic (linear) / ·acquisition fold (linear) [part of ACQ] / ·ngs wfs dichroic (linear) [part of NGSWFS] / ·instrument select (rotary) / Software: / ·3x linear device controllers / ·1x rotary device controller

| ID | WBS | Task | Duration | Start | Finish | Total slack | Resources | Work | Cost | Text1 |
| --- | --- | --- | --- | --- | --- | --- | --- | --- | --- | --- |
| 25 | 1.1.1.8 | **NGS Wavefront Sensor** | 15d | 2010-06-21 | 2010-07-09 | 45d |  | 240h | 18,500 | NGSWFS |
| 26 | 1.1.1.8.1 | Electronics | 2w | 2010-06-21 | 2010-07-09 | 45d | EE; Motion Device [700%]; Device [900%] | 80h | 18,500 |  |
| 27 | 1.1.1.8.2 | Software | 3w | 2010-06-21 | 2010-07-09 | 45d | SW MC; SW AO | 160h |  |  |
| 28 | 1.1.1.9 | **Atmospheric Dispersion Corrector** | 10d | 2010-06-21 | 2010-07-02 | 50d |  | 180h | 6,000 | ADC |
| 29 | 1.1.1.9.1 | Electronics | 2w | 2010-06-21 | 2010-07-02 | 50d | EE; Motion Device [300%] | 80h | 6,000 |  |
| 30 | 1.1.1.9.2 | Software | 2w | 2010-06-21 | 2010-07-02 | 50d | SW MC; SW AO | 100h |  |  |
| 31 | 1.1.1.10 | **AO Enclosures** | 40d | 2010-06-21 | 2010-08-13 | 20d |  | 920h | 45,000 | ENC |
| 32 | 1.1.1.10.1 | **Electronics** | 40d | 2010-06-21 | 2010-08-13 | 20d |  | 760h | 45,000 |  |
| 33 | 1.1.1.10.1.1 | AO Room (inc: input and output hatches) | 2w | 2010-06-21 | 2010-07-02 | 50d | EE; ET; Device [4000%] | 160h | 20,000 |  |
| 34 | 1.1.1.10.1.2 | AO Electronics Vault | 8w | 2010-06-21 | 2010-08-13 | 20d | EE; Device [3000%] | 320h | 15,000 |  |
| 35 | 1.1.1.10.1.3 | AO Cold Enclosure (Bench) | 7w | 2010-06-21 | 2010-08-06 | 25d | EE; Device [2000%] | 280h | 10,000 |  |
| 36 | 1.1.1.10.2 | Software | 4w | 2010-06-21 | 2010-07-16 | 40d | SW MC | 160h |  |  |
| 37 | 1.1.1.11 | AO Control Sequencer | 8w | 2010-06-21 | 2010-08-13 | 20d | SW AO | 320h |  | AOSEQ |
| 38 | 1.1.1.12 | RTC Interface | 10d? | 2010-06-21 | 2010-07-02 | 50d | SW | 80h |  |  |
| 39 | 1.1.1.13 | Atmospheric Profiler Interface | 5d? | 2010-06-21 | 2010-06-25 | 55d | SW | 40h |  |  |
| 40 | 1.1.2 | **Laser Guide Star Facility Control System** | 40d? | 2010-06-21 | 2010-08-13 | 20d |  | 1600h | 70,000 |  |
| 41 | 1.1.2.1 | **Laser Controller Interface** | 10d? | 2010-06-21 | 2010-07-02 | 50d |  | 100h | 500 | LIF |
| 42 | 1.1.2.1.1 | Communication Cabling | 2.5d? | 2010-06-21 | 2010-06-23 | 57.5d | EE; Device | 20h | 500 |  |
| 43 | 1.1.2.1.2 | Control / Status Interface | 10d? | 2010-06-21 | 2010-07-02 | 50d | SW MC | 80h |  |  |
| 44 | 1.1.2.2 | **Laser Switchyard** | 10d? | 2010-06-21 | 2010-07-02 | 50d |  | 200h | 25,000 | LSY |
| 45 | 1.1.2.2.1 | Electronics | 10d? | 2010-06-21 | 2010-07-02 | 50d | EE; Motion Device [1000%]; Device [1000%] | 80h | 25,000 |  |
| 46 | 1.1.2.2.2 | Software | 10d? | 2010-06-21 | 2010-07-02 | 50d | SW MC; SW AO | 120h |  |  |
| 47 | 1.1.2.3 | **Laser Beam Generation System** | 30d? | 2010-06-21 | 2010-07-30 | 30d |  | 520h | 39,500 | BGS |
| 48 | 1.1.2.3.1 | Electronics | 20d? | 2010-06-21 | 2010-07-16 | 40d | EE; Motion Device [1600%]; Device [1500%] | 160h | 39,500 |  |
| 49 | 1.1.2.3.2 | Software | 30d? | 2010-06-21 | 2010-07-30 | 30d | SW MC; SW AO | 360h |  |  |

Notes:
- 25: Hardware: / ·2x wfs fsm (2dof: tip/tilt) / ·wfs lenslet (2dof: linear) / ·focus stage (linear) / ·collision avoidance mechanism between lenslet and focus stage / Software: / ·2dof device controllers for fsms and lenslet / ·device controller for focus stage / ·supervisory controller: there will have to be some serious thought about how to coordinate offloading / tip-tilt correction between TTM2 and FSMs. Based on Eds comment about focus and lenslet stage collision it seems like the supervisory controller will have to be more intelligent than I originally assumed.
- 28: Detailed design and documenation base on assumptions of what it is / Hardware: / ·adc (2dof: either rotary or linear) / ·linear stage / Software: / ·2dof device controller (custom?) / ·linear stage device controller / ·high level controller (actively controlling positions)
- 33: Large room on the Keck Telescope Nasmyth platform containing the AO system, for NGAO it will be climate controlled. Temperature will be ~dome ambient, nominally 0 degrees Celsius +/- 10 degrees. / ·room temperature / ·humidity / ·dust / ·rack/equipment temperatures / ·camera / ·A/C controls / ·HEPA controls / ·lights controls / ·input hatch* / ·interferometer output hatch*
- 34: Large room containing electronics that support operation of the AO system. Room is keep at a warmer temperature than the AO Room, ~17 degrees Celsius (63 degrees Fahrenheit). Waste heat is removed by a cooling system. The Electronics Vault must be thermally isolated to some degree from adjoining AO Room. Frequently abbreviated e-vault. / ·glycol flow / ·temperature / ·ca/sim source output / ·cal/sim source power / ·cal/sim source intensity readback / ·motion control local/remote / ·motion control status / ·ac controls / ·racks / ·cabling
- 35: Smaller enclosure that surrounds the AO system bench and is cooled to approximately -15 degree Celsius to reduce emissivity (background) for infrared wavelength observations. (Note that the exact temperature of the AO Cold Enclosure is subject to change as design progresses). Previously referred to as the cold box. / ·temperature / ·humidity / ·dust / ·video camera / ·accels / ·IF IBM-T source / ·lights control / ·racks / ·cabling
- 36: Software: / ·readback for: / ·temperature/ ·humidity/ ·dust/ ·cal/sim source intensity / ·control and readback for: / ·accels/ ·AC/ ·HEPA/ ·lights/ ·motion control/ ·cal/sim source / ·surveillance camera controls
- 37: High level AO control sequencer. / Interfaces to higher level operations level controllers and coordinates and controls lower level AO device controllers accordingly. Lots of sequences need to be understood and developed.
- 41: Detailed design and documentation for interfacing to the vendor supplied laser controller. / Will be reading statuses and sending commands to laser controller. No automated control loops are envisioned at this time.
- 44: Hardware: / ·3x polarizing 1/4 waveplate (1dof: rotary) / ·3x polarizing 1/2 waveplate (1dof: rotary) / ·3x pointing/steering mirrors (2dof: tip/tilt) / ·alignment beamsplitter (1dof: linear) / Software: / ·6x device controllers for rotary devices / ·3x 2dof device controllers for pointing/steering mirrors / ·linear device controller / ·supervisory sequencer
- 47: Hardware: / ·2x beam splitter (1dof: linear) / ·imager pickoff (1dof: linear) / ·3x patrolling lgs steering (2dof: linear) / ·asterism rotator (1dof: rotary) / ·asterism tip/tilt (2dof: tipt/tilt) / ·fast shutter / ·focus stage (1dof: linear) / ·lto polarization sensor (2dof: rotary) / ·lto cover (1dof: ?) / ·beam wfs / ·power / ·polarization sensor / ·beam position sensor / ·AC controls / ·temperature / ·humidity / Software: / ·5x 1dof linear device controllers / ·3x 2dof linear device controllers / ·1dof rotary device controller / ·2dof rotary device controller / ·2dof tip/tilt device controller / ·shutter type device control / ·non-motion device status and control / ·high level control sequencer (5wks)

| ID | WBS | Task | Duration | Start | Finish | Total slack | Resources | Work | Cost | Text1 |
| --- | --- | --- | --- | --- | --- | --- | --- | --- | --- | --- |
| 50 | 1.1.2.4 | **Laser Safety System** | 15d? | 2010-06-21 | 2010-07-09 | 45d |  | 240h |  | LSS |
| 51 | 1.1.2.4.1 | Electronics | 1d? | 2010-06-21 | 2010-06-21 | 59d |  |  |  |  |
| 52 | 1.1.2.4.2 | **Software** | 15d? | 2010-06-21 | 2010-07-09 | 45d |  | 240h |  |  |
| 53 | 1.1.2.4.2.1 | Safety System Interface | 10d? | 2010-06-21 | 2010-07-02 | 50d | SW MC | 80h |  |  |
| 54 | 1.1.2.4.2.2 | LTCS | 15d? | 2010-06-21 | 2010-07-09 | 45d | SW AO | 120h |  |  |
| 55 | 1.1.2.4.2.3 | Laser Clearinghouse | 5d? | 2010-06-21 | 2010-06-25 | 55d | SW AO | 40h |  |  |
| 56 | 1.1.2.5 | **Laser Service Enclosure** | 15d? | 2010-06-21 | 2010-07-09 | 45d |  | 220h | 5,000 | LSE |
| 57 | 1.1.2.5.1 | Electronics | 10d? | 2010-06-21 | 2010-07-09 | 45d | EE; ET; Device [1000%] | 160h | 5,000 |  |
| 58 | 1.1.2.5.2 | Software | 7.5d? | 2010-06-21 | 2010-06-30 | 52.5d | SW MC | 60h |  |  |
| 59 | 1.1.2.6 | Laser Beam Transport Optics | 1d? | 2010-06-21 | 2010-06-21 | 59d |  |  |  |  |
| 60 | 1.1.2.7 | Laser Control Sequencer | 40d? | 2010-06-21 | 2010-08-13 | 20d | SW AO | 320h |  |  |
| 61 | 1.1.3 | **Control System Infrastructure** | 60d? | 2010-06-21 | 2010-09-10 | 0d |  | 2900h | 56,500 |  |
| 62 | 1.1.3.1 | **Motion Control** | 40d? | 2010-06-21 | 2010-08-13 | 20d |  | 480h | 8,000 |  |
| 63 | 1.1.3.1.1 | Electronics | 10d? | 2010-06-21 | 2010-07-02 | 50d | EE; ET; Motion Device [400%] | 160h | 8,000 |  |
| 64 | 1.1.3.1.2 | Software | 40d? | 2010-06-21 | 2010-08-13 | 20d | SW MC | 320h |  |  |
| 65 | 1.1.3.2 | **Device Control** | 40d? | 2010-06-21 | 2010-08-13 | 20d |  | 640h | 5,000 |  |
| 66 | 1.1.3.2.1 | Electronics | 20d? | 2010-06-21 | 2010-07-16 | 40d | EE; ET; Device [1000%] | 320h | 5,000 |  |
| 67 | 1.1.3.2.2 | Software | 40d? | 2010-06-21 | 2010-08-13 | 20d | SW MC | 320h |  |  |
| 68 | 1.1.3.3 | **Monitoring** | 1d? | 2010-06-21 | 2010-06-21 | 59d |  |  |  | MON |
| 69 | 1.1.3.3.1 | Vibration | 1d? | 2010-06-21 | 2010-06-21 | 59d |  |  |  |  |
| 70 | 1.1.3.3.2 | Temperature | 1d? | 2010-06-21 | 2010-06-21 | 59d |  |  |  |  |
| 71 | 1.1.3.3.3 | Humidity | 1d? | 2010-06-21 | 2010-06-21 | 59d |  |  |  |  |
| 72 | 1.1.3.3.4 | Dust | 1d? | 2010-06-21 | 2010-06-21 | 59d |  |  |  |  |
| 73 | 1.1.3.4 | **Electronics** | 5d? | 2010-06-21 | 2010-06-25 | 55d |  | 180h | 3,500 |  |
| 74 | 1.1.3.4.1 | Instrument Interface | 5d? | 2010-06-21 | 2010-06-25 | 55d | EE; Device | 40h | 500 |  |
| 75 | 1.1.3.4.2 | Interferometer Interface | 2.5d? | 2010-06-21 | 2010-06-23 | 57.5d | EE; Device | 20h | 500 |  |
| 76 | 1.1.3.4.3 | Control Computers | 2.5d? | 2010-06-21 | 2010-06-23 | 57.5d | EE; Device | 20h | 500 |  |
| 77 | 1.1.3.4.4 | Realtime Control Computers | 5d? | 2010-06-21 | 2010-06-25 | 55d | EE; Device | 40h | 500 |  |
| 78 | 1.1.3.4.5 | Time Infrastructure (Sync) | 5d? | 2010-06-21 | 2010-06-25 | 55d | EE; Device [200%] | 40h | 1,000 |  |
| 79 | 1.1.3.4.6 | Communication Infrastructure | 2.5d? | 2010-06-21 | 2010-06-23 | 57.5d | EE; Device | 20h | 500 |  |

Notes:
- 51: Don't think there's anything here for Ed to do... I'm assuming Jason will be responsible for installing and making this work under his WBS.
- 53: Detailed design and documenation for interfacing to laser safety system.
- 54: per JC: Need to make existing code work with 7beams and transfer to new system, see: / http://www.oir.caltech.edu/twiki_oir/pub/Keck/NGAO/LaserPDRPhase/NGAO_LTCS_Modification_Preliiminary_Design_DS.doc / DSummers estimate: DD 32hrs, FSD 100hrs / reference documents: / http://keckshare.keck.hawaii.edu/dsweb/Get/Document-35985/KAON713.doc/ http://keckshare.keck.hawaii.edu/dsweb/Get/Document-7474/SDF_KECK_LTCS_URLs.doc/ http://keckshare.keck.hawaii.edu/dsweb/Get/Document-7472/SDF_revised_draft.doc
- 55: per JC: Transfer existing tool to new system, see: http://www.oir.caltech.edu/twiki_oir/pub/Keck/NGAO/LaserPDRPhase/NGAO_Laser_Clearing_House_Planning.doc
- 56: Hardware: / ·beam dump / ·temperature / ·humidity / ·dust / ·video camera / ·AC controls / Software: / ·non-motion device status and controls
- 59: This is being handled by the MRI proposal and JC has it covered.
- 60: Detailed design and documentation for high level laser control sequencer. / Interfaces to higher level operations level controllers and coordinates and controls lower level laser device controllers accordingly.
- 62: Motion device control. / Hardware: / ·platform selection / ·motion controller selection / ·motion controller locations / ·amplifiers / ·wiring / ·etc... / Software: / ·software interface / · low level device controller / ·device control state machine / · low level engineering gui interface
- 65: Non-motion device control. / Hardware: / ·controller selection / ·temperature / ·humidity / ·dust/ ·wiring / ·video camera / ·power / ·etc... / Software: / ·device drivers for each type / ·interface definition / ·attribute definitions / ·method definition / ·etc...
- 68: The bulk of this would be done under "Device Control" for hardware selection and software driver stuff. With the actual monitoring falling uder the various enclosures.

| ID | WBS | Task | Duration | Start | Finish | Total slack | Resources | Work | Cost | Text1 |
| --- | --- | --- | --- | --- | --- | --- | --- | --- | --- | --- |
| 80 | 1.1.3.5 | **Software** | 50d? | 2010-06-21 | 2010-08-27 | 10d |  | 1080h |  | INFR |
| 81 | 1.1.3.5.1 | Health Monitoring | 10d? | 2010-06-21 | 2010-07-02 | 50d | SW | 80h |  |  |
| 82 | 1.1.3.5.2 | Logging | 10d? | 2010-06-21 | 2010-07-02 | 50d | SW | 80h |  |  |
| 83 | 1.1.3.5.3 | Archiving | 10d? | 2010-06-21 | 2010-07-02 | 50d | SW | 80h |  |  |
| 84 | 1.1.3.5.4 | Alarming | 15d? | 2010-06-21 | 2010-07-09 | 45d | SW | 120h |  |  |
| 85 | 1.1.3.5.5 | Configuration | 30d? | 2010-06-21 | 2010-07-30 | 30d | SW | 240h |  |  |
| 86 | 1.1.3.5.6 | Keyword Interface | 5d? | 2010-06-21 | 2010-06-25 | 55d | SW | 40h |  |  |
| 87 | 1.1.3.5.7 | EPICS Channel Access Interface | 5d? | 2010-06-21 | 2010-06-25 | 55d | SW | 40h |  |  |
| 88 | 1.1.3.5.8 | Utility Scripts | 50d? | 2010-06-21 | 2010-08-27 | 10d | SW | 400h |  |  |
| 89 | 1.1.3.6 | **Data Server** | 60d? | 2010-06-21 | 2010-09-10 | 0d |  | 520h | 40,000 | DS |
| 90 | 1.1.3.6.1 | Software | 60d? | 2010-06-21 | 2010-09-10 | 0d | SW | 480h |  |  |
| 91 | 1.1.3.6.2 | Hardware Setup | 5d? | 2010-06-21 | 2010-06-25 | 55d | SW; Sun Storage 7210 | 40h | 40,000 |  |

Notes:
- 85: ·config Server / ·database design / ·config snapshot / ·gui
- 88: Library of common functions / tasks for observers, SA, developers, etc... / Still needs to be defined but I stuck a number in for now.
- 89: Detailed design and documentation including recommended computer/disk hardware selection. / Computers: 1wk / Software: 12wks / ·database definition and design / ·log files definition and design / ·interface tool specs and design / ·inter-process comm spec and design
