# NGAO Development

Schedule from MS Project, 2005-10-03 to 2015-10-30.
CARA

## Calendars

- Standard: Mon-Fri 08:00-12:00, 13:00-17:00; Sat-Sun off.

## Resources

| Resource |
| --- |
| EE |
| SW MC |
| SW AO |
| SW |

## Schedule

| ID | WBS | Task | Type | Duration | Start | Finish | Predecessors | Total slack | Free slack | Constraint |
| --- | --- | --- | --- | --- | --- | --- | --- | --- | --- | --- |
| 1 | 1 | **NGAO Design** |  | 1825d? | 2005-10-03 | 2012-09-28 |  | 538d |  |  |
| 2 | 1.1 | Proposal |  | 195d? | 2005-10-03 | 2006-06-30 |  | 538d | 65d | start no earlier than 2005-10-03 |
| 3 | 1.2 | System Design |  | 413d? | 2006-10-02 | 2008-04-30 | 2 | 473d | 0d | start no earlier than 2006-10-02 |
| 4 | 1.3 | **Preliminary Design +** |  | 631d? | 2008-05-01 | 2010-09-30 |  | 473d |  |  |
| 5 | 1.3.1 | Preliminary Design |  | 565d? | 2008-05-01 | 2010-06-30 | 3 | 473d | 0d | start no earlier than 2008-05-01 |
| 6 | 1.3.2 | **Preliminary Design Revisions** |  | 66d? | 2010-07-01 | 2010-09-30 | 5 | 473d |  |  |
| 7 | 1.3.2.1 | Response to PDR Reviewer Report |  | 22d? | 2010-07-01 | 2010-07-30 |  | 1370d |  | start no earlier than 2010-07-01 |
| 8 | 1.3.2.2 | Plan Revisions |  | 54d? | 2010-07-19 | 2010-09-30 |  | 461d | 0d | finish no earlier than 2010-09-30 |
| 9 | 1.4 | Detailed Design |  | 521d? | 2010-10-01 | 2012-09-28 | 8 | 461d | 0d | finish no earlier than 2012-09-28 |
| 10 | 2 | **Project Management** |  | 805d? | 2012-10-01 | 2015-10-30 | 9 | 0d |  |  |
| 11 | 2.1 | Planning |  | 1d? | 2012-10-01 | 2012-10-01 |  | 804d |  |  |
| 12 | 2.2 | Project Management & Meetings |  | 1d? | 2012-10-01 | 2012-10-01 |  | 804d |  |  |
| 13 | 2.3 | Tracking & Reporting |  | 1d? | 2012-10-01 | 2012-10-01 |  | 804d |  |  |
| 14 | 2.4 | Proposals & Fundraising |  | 1d? | 2012-10-01 | 2012-10-01 |  | 804d |  |  |
| 15 | 2.5 | Programmatic Risk Assessment & Mitigation |  | 1d? | 2012-10-01 | 2012-10-01 |  | 804d |  |  |
| 16 | 2.6 | **Project Reviews** |  | 805d? | 2012-10-01 | 2015-10-30 |  | 0d |  |  |
| 17 | 2.6.1 | Subsystem Acceptance Reviews |  | 1d? | 2012-10-01 | 2012-10-01 |  | 804d |  |  |
| 18 | 2.6.2 | AO System Pre-Lab I&T Readiness Review | milestone | 0d | 2013-09-24 | 2013-09-24 | 161FS+2d | 548d |  | start no earlier than 2013-03-22 |
| 19 | 2.6.3 | Science Instrument Pre-Lab I&T Readiness Review | milestone | 0d | 2014-03-31 | 2014-03-31 |  | 375d | 0d | start no earlier than 2014-03-31 |
| 20 | 2.6.4 | AO System Pre-Telescope I&T Readiness Review | milestone | 0d | 2014-11-26 | 2014-11-26 | 193FS+3d | 0d |  | start no earlier than 2014-09-22 |
| 21 | 2.6.5 | Laser System Pre-Telescope I&T Readiness Review | milestone | 0d | 2013-05-31 | 2013-05-31 | 203FS-11d | 514d | 11d |  |
| 22 | 2.6.6 | NGAO Operability Review | milestone | 0d | 2015-09-25 | 2015-09-25 | 386 | 25d |  |  |
| 23 | 2.6.7 | NGAO Operations Readiness Review | milestone | 0d | 2015-10-30 | 2015-10-30 | 388, 394 | 0d |  |  |
| 24 | 2.7 | Project Support |  | 1d? | 2012-10-01 | 2012-10-01 |  | 804d |  |  |

| ID | WBS | Task | Duration | Start | Finish | Predecessors | Total slack | Free slack | Constraint |
| --- | --- | --- | --- | --- | --- | --- | --- | --- | --- |
| 25 | 3 | **Systems Engineering** | 1d? | 2012-10-01 | 2012-10-01 | 9 | 804d |  |  |
| 26 | 3.1 | Science Case Requirements | 1d? | 2012-10-01 | 2012-10-01 |  | 804d |  |  |
| 27 | 3.2 | Requirements | 1d? | 2012-10-01 | 2012-10-01 |  | 804d |  |  |
| 28 | 3.3 | Systems Engineering Analysis | 1d? | 2012-10-01 | 2012-10-01 |  | 804d |  |  |
| 29 | 3.4 | Interface Control | 1d? | 2012-10-01 | 2012-10-01 |  | 804d |  |  |
| 30 | 3.5 | Configuration Control | 1d? | 2012-10-01 | 2012-10-01 |  | 804d |  |  |
| 31 | 3.6 | Technical Risk Assessment & Mitigation | 1d? | 2012-10-01 | 2012-10-01 |  | 804d |  |  |
| 32 | 3.7 | Design Manual | 1d? | 2012-10-01 | 2012-10-01 |  | 804d |  |  |
| 33 | 4 | **AO System** | 560d? | 2012-10-01 | 2014-11-21 | 9 | 245d |  |  |
| 34 | 4.1 | **AO Enclosure** | 240d? | 2012-10-01 | 2013-08-30 |  | 565d |  |  |
| 35 | 4.1.1 | **AO Room** | 130d? | 2013-03-04 | 2013-08-30 |  | 565d |  |  |
| 36 | 4.1.1.1 | AO Room Modifications Procurements/Fabrication | 130d? | 2013-03-04 | 2013-08-30 |  | 565d |  | finish no earlier than 2013-08-30 |
| 37 | 4.1.2 | **Electronics Vault** | 130d? | 2013-03-04 | 2013-08-30 |  | 565d |  |  |
| 38 | 4.1.2.1 | Electronics Vault Modifications Procurements/Fabrication | 130d? | 2013-03-04 | 2013-08-30 |  | 565d |  | finish no earlier than 2013-08-30 |
| 39 | 4.1.3 | **AO Bench Cold Enclosure** | 230d? | 2012-10-01 | 2013-08-16 |  | 568d | 0d |  |
| 40 | 4.1.3.1 | Cold Enclosure Procurements/Fabrication | 175d? | 2012-10-01 | 2013-05-31 |  | 623d |  | start no earlier than 2012-10-01 |
| 41 | 4.1.3.2 | Cold Enclosure Assembly (in lab) | 10d? | 2013-07-01 | 2013-07-12 |  | 568d | 0d | finish no earlier than 2013-07-12 |
| 42 | 4.1.3.3 | Cold Enclosure Testing & Characterization | 25d? | 2013-07-15 | 2013-08-16 | 41 | 568d |  | finish no earlier than 2013-08-16 |
| 43 | 4.2 | **AO Bench** | 261d? | 2012-10-01 | 2013-09-30 |  | 544d |  |  |
| 44 | 4.2.1 | **AO Bench (AOB) Support Structure (SS)** | 195d? | 2012-10-01 | 2013-06-28 |  | 610d | 0d |  |
| 45 | 4.2.1.1 | **AOB SS Procurements/Fabrication** | 175d? | 2012-10-01 | 2013-05-31 |  | 620d |  |  |
| 46 | 4.2.1.1.1 | Optical Bench Procurement | 175d? | 2012-10-01 | 2013-05-31 |  | 620d | 10d | start no earlier than 2012-10-01 |
| 47 | 4.2.1.1.2 | Lab Support Legs | 175d? | 2012-10-01 | 2013-05-31 |  | 630d |  | finish no earlier than 2013-05-31 |
| 48 | 4.2.1.1.3 | Telescope Support Legs | 175d? | 2012-10-01 | 2013-05-31 |  | 630d |  | finish no earlier than 2013-05-31 |
| 49 | 4.2.1.2 | AOB SS Assembly | 5d? | 2013-06-17 | 2013-06-21 | 46 | 610d | 0d | finish no earlier than 2013-06-21 |
| 50 | 4.2.1.3 | AOB SS Test & Acceptance | 5d? | 2013-06-24 | 2013-06-28 | 49 | 610d |  | finish no earlier than 2013-06-28 |

| ID | WBS | Task | Duration | Start | Finish | Predecessors | Total slack | Free slack | Constraint |
| --- | --- | --- | --- | --- | --- | --- | --- | --- | --- |
| 51 | 4.2.2 | **Entrance & Exit Windows** | 125d? | 2012-11-05 | 2013-04-26 |  | 655d |  |  |
| 52 | 4.2.2.1 | **Windows Procurements/Fabrication** | 85d? | 2012-11-05 | 2013-03-01 |  | 695d |  |  |
| 53 | 4.2.2.1.1 | Entrance Window | 85d? | 2012-11-05 | 2013-03-01 |  | 695d |  | finish no earlier than 2013-03-01 |
| 54 | 4.2.2.1.2 | LGS WFS Exit Window | 85d? | 2012-11-05 | 2013-03-01 |  | 695d |  | start no earlier than 2012-11-05 |
| 55 | 4.2.2.1.3 | Interferometer Exit Windows | 85d? | 2012-11-05 | 2013-03-01 |  | 695d |  | start no earlier than 2012-11-05 |
| 56 | 4.2.2.1.4 | Window Cells | 85d? | 2012-11-05 | 2013-03-01 |  | 695d |  | start no earlier than 2012-11-05 |
| 57 | 4.2.2.2 | Windows Testing & Characterization | 20d? | 2013-03-04 | 2013-03-29 |  | 675d |  | finish no earlier than 2013-03-29 |
| 58 | 4.2.2.3 | Windows Assembly & Alignment | 20d? | 2013-04-01 | 2013-04-26 |  | 655d |  | finish no earlier than 2013-04-26 |
| 59 | 4.2.3 | **Rotator** | 175d? | 2012-10-01 | 2013-05-31 |  | 630d |  |  |
| 60 | 4.2.3.1 | Rotator Procurements/Fabrication | 130d? | 2012-10-01 | 2013-03-29 |  | 675d |  | start no earlier than 2012-10-01 |
| 61 | 4.2.3.2 | Rotator Assembly & Alignment | 50d? | 2013-02-25 | 2013-05-03 |  | 630d | 0d | finish no earlier than 2013-05-03 |
| 62 | 4.2.3.3 | Rotator Testing & Characterization | 20d? | 2013-05-06 | 2013-05-31 | 61 | 630d |  | start no earlier than 2013-05-06 |
| 63 | 4.2.4 | **Wide Field Relay** | 220d? | 2012-10-01 | 2013-08-02 |  | 585d |  |  |
| 64 | 4.2.4.1 | Wide Field Relay Procurements/Fabrication | 175d? | 2012-10-01 | 2013-05-31 |  | 590d | 5d | start no earlier than 2012-10-01 |
| 65 | 4.2.4.2 | Wide Field Relay Assembly & Alignment | 20d? | 2013-06-10 | 2013-07-05 | 64, 139 | 585d | 0d | finish no earlier than 2013-06-28 |
| 66 | 4.2.4.3 | Wide Field Relay Testing & Characterization | 20d? | 2013-07-08 | 2013-08-02 | 65 | 585d |  | start no earlier than 2013-07-01 |
| 67 | 4.2.5 | **LGS WFS Feed** | 185d? | 2012-10-01 | 2013-06-14 |  | 620d |  |  |
| 68 | 4.2.5.1 | **LGS WFS Feed Procurements/Fabrication** | 150d? | 2012-10-01 | 2013-04-26 |  | 655d |  |  |
| 69 | 4.2.5.1.1 | LGS Dichroic | 150d? | 2012-10-01 | 2013-04-26 |  | 655d |  | start no earlier than 2012-10-01 |
| 70 | 4.2.5.1.2 | Fold Mirror | 75d? | 2013-01-07 | 2013-04-19 |  | 660d |  | finish no earlier than 2013-04-19 |
| 71 | 4.2.5.1.3 | Reimaging Lens | 120d? | 2012-11-05 | 2013-04-19 |  | 660d |  | finish no earlier than 2013-04-19 |
| 72 | 4.2.5.1.4 | Mounting Hardware | 70d? | 2013-01-07 | 2013-04-12 |  | 665d |  | finish no earlier than 2013-04-12 |
| 73 | 4.2.5.2 | LGS WFS Feed Assembly & Alignment | 20d? | 2013-05-06 | 2013-05-31 |  | 620d | 0d | finish no earlier than 2013-05-31 |
| 74 | 4.2.5.3 | LGS WFS Feed Testing & Characterization | 10d? | 2013-06-03 | 2013-06-14 | 73 | 620d |  | finish no earlier than 2013-06-14 |

| ID | WBS | Task | Duration | Start | Finish | Predecessors | Total slack | Free slack | Constraint |
| --- | --- | --- | --- | --- | --- | --- | --- | --- | --- |
| 75 | 4.2.6 | **Narrow Field Relay** | 230d? | 2012-10-01 | 2013-08-16 |  | 575d |  |  |
| 76 | 4.2.6.1 | Narrow Field Relay Procurements/Fabrication | 175d? | 2012-10-01 | 2013-05-31 |  | 585d | 10d | start no earlier than 2012-10-01 |
| 77 | 4.2.6.2 | Narrow Field Relay Assembly & Alignment | 25d? | 2013-06-17 | 2013-07-19 | 76, 140 | 575d | 0d | finish no earlier than 2013-07-19 |
| 78 | 4.2.6.3 | Narrow Field Relay Testing & Characterization | 20d? | 2013-07-22 | 2013-08-16 | 77 | 575d |  | finish no earlier than 2013-08-16 |
| 79 | 4.2.7 | **Optical Switchyard (OS)** | 150d? | 2012-12-03 | 2013-06-28 |  | 610d |  |  |
| 80 | 4.2.7.1 | **OS Procurements/Fabrication** | 105d? | 2012-12-03 | 2013-04-26 |  | 655d |  |  |
| 81 | 4.2.7.1.1 | Interferometer Dichroic | 105d? | 2012-12-03 | 2013-04-26 |  | 655d |  | finish no earlier than 2013-04-26 |
| 82 | 4.2.7.1.2 | Acquisition Mirror | 105d? | 2012-12-03 | 2013-04-26 |  | 655d |  | start no earlier than 2012-12-03 |
| 83 | 4.2.7.1.3 | NGS WFS Dichroic | 105d? | 2012-12-03 | 2013-04-26 |  | 655d |  | start no earlier than 2012-12-03 |
| 84 | 4.2.7.1.4 | Mounting Hardware | 105d? | 2012-12-03 | 2013-04-26 |  | 655d |  | start no earlier than 2012-12-03 |
| 85 | 4.2.7.1.5 | Translation Stages | 105d? | 2012-12-03 | 2013-04-26 |  | 655d |  | start no earlier than 2012-12-03 |
| 86 | 4.2.7.2 | OS Assembly & Alignment | 25d? | 2013-04-29 | 2013-05-31 |  | 630d |  | finish no earlier than 2013-05-31 |
| 87 | 4.2.7.3 | OS Testing & Characterization | 20d? | 2013-06-03 | 2013-06-28 |  | 610d |  | finish no earlier than 2013-06-28 |
| 88 | 4.2.8 | **Atmospheric Dispersion Corrector (ADC)** | 165d? | 2012-11-12 | 2013-06-28 |  | 610d |  |  |
| 89 | 4.2.8.1 | ADC Procurements/Fabrication | 120d? | 2012-11-12 | 2013-04-26 |  | 610d | 0d | finish no earlier than 2013-04-26 |
| 90 | 4.2.8.2 | ADC Assembly & Alignment | 20d? | 2013-04-29 | 2013-05-24 | 89 | 610d | 0d | start no earlier than 2013-04-29 |
| 91 | 4.2.8.3 | ADC Testing & Characterization | 25d? | 2013-05-27 | 2013-06-28 | 90 | 610d |  | start no earlier than 2013-05-27 |
| 92 | 4.2.9 | AO Bench Component Acceptance Review | 5d? | 2013-09-09 | 2013-09-13 |  | 487d | 0d | finish no earlier than 2013-09-13 |
| 93 | 4.2.10 | **AO Bench Component Packing & Shipping** | 11d? | 2013-09-16 | 2013-09-30 | 92 | 487d |  |  |
| 94 | 4.2.10.1 | AO Bench Component Packing | 5d? | 2013-09-16 | 2013-09-20 |  | 487d | 0d | start no earlier than 2013-09-16 |
| 95 | 4.2.10.2 | AO Bench Component Shipping to WMKO | 6d? | 2013-09-23 | 2013-09-30 | 94 | 487d | 0d | start no earlier than 2013-09-23 |
| 96 | 4.3 | **LGS WFS Assembly** | 281d? | 2012-10-01 | 2013-10-28 |  | 524d |  |  |
| 97 | 4.3.1 | LGS WFS Procurements/Fabrication | 130d? | 2012-10-01 | 2013-03-29 |  | 675d |  | start no earlier than 2012-10-01 |
| 98 | 4.3.2 | LGS WFS Assembly & Align | 150d? | 2012-12-03 | 2013-06-28 |  | 511d | 0d | finish no earlier than 2013-06-28 |
| 99 | 4.3.3 | LGS WFS Testing & Characterization | 65d? | 2013-07-01 | 2013-09-27 | 98 | 511d | 0d | start no earlier than 2013-07-01 |
| 100 | 4.3.4 | LGS WFS Acceptance Review | 1d? | 2013-10-07 | 2013-10-07 | 99FS+5d | 511d | 0d |  |

| ID | WBS | Task | Duration | Start | Finish | Predecessors | Total slack | Free slack | Constraint |
| --- | --- | --- | --- | --- | --- | --- | --- | --- | --- |
| 101 | 4.3.5 | **LGS WFS Shipping to WMKO** | 10d? | 2013-10-15 | 2013-10-28 |  | 511d | 14d |  |
| 102 | 4.3.5.1 | LGS WFS Packing | 5d? | 2013-10-15 | 2013-10-21 | 100FS+5d | 511d | 0d | start no earlier than 2013-10-15 |
| 103 | 4.3.5.2 | LGS WFS Shipping to WMKO | 5d? | 2013-10-22 | 2013-10-28 | 102 | 511d |  | start no earlier than 2012-10-01 |
| 104 | 4.4 | **NGS WFS Assembly** | 170d? | 2012-10-01 | 2013-05-24 |  | 635d |  |  |
| 105 | 4.4.1 | NGS WFS Procurements/Fabrication | 90d? | 2012-10-01 | 2013-02-01 |  | 715d |  | start no earlier than 2012-10-01 |
| 106 | 4.4.2 | NGS WFS Assembly & Align | 65d? | 2012-12-03 | 2013-03-01 |  | 602d | 0d | start no earlier than 2012-12-03 |
| 107 | 4.4.3 | NGS WFS Testing & Characterization | 45d? | 2013-03-04 | 2013-05-03 | 106 | 602d | 0d | start no earlier than 2013-03-04 |
| 108 | 4.4.4 | NGS WFS Acceptance Review | 1d? | 2013-05-13 | 2013-05-13 | 107FS+5d | 602d | 0d |  |
| 109 | 4.4.5 | **NGS WFS Packing & Shipping** | 9d? | 2013-05-14 | 2013-05-24 |  | 602d |  |  |
| 110 | 4.4.5.1 | NGS WFS Packing | 4d? | 2013-05-14 | 2013-05-17 | 108 | 602d | 0d | start no earlier than 2013-05-14 |
| 111 | 4.4.5.2 | NGS WFS Shipping to WMKO | 5d? | 2013-05-20 | 2013-05-24 | 110 | 602d | 115d | finish no earlier than 2013-05-24 |
| 112 | 4.5 | **LOWFS Assembly** | 270d? | 2012-10-01 | 2013-10-11 |  | 535d |  |  |
| 113 | 4.5.1 | LOWFS Procurements/Fabrication | 130d? | 2012-10-01 | 2013-03-29 |  | 675d |  | start no earlier than 2012-10-01 |
| 114 | 4.5.2 | LOWFS Assembly & Align | 130d? | 2012-12-03 | 2013-05-31 |  | 516d | 0d | finish no earlier than 2013-05-31 |
| 115 | 4.5.3 | LOWFS Testing & Characterization | 75d? | 2013-06-03 | 2013-09-13 | 114 | 516d | 0d | start no earlier than 2013-06-03 |
| 116 | 4.5.4 | LOWFS Acceptance Review | 1d? | 2013-09-23 | 2013-09-23 | 115FS+5d | 516d | 0d |  |
| 117 | 4.5.5 | **LOWFS Shipping to WMKO** | 10d? | 2013-09-30 | 2013-10-11 |  | 516d | 18d |  |
| 118 | 4.5.5.1 | LOWFS Packing | 5d? | 2013-09-30 | 2013-10-04 | 116FS+4d | 516d | 0d | start no earlier than 2013-09-30 |
| 119 | 4.5.5.2 | LOWFS Packing & Shipping | 5d? | 2013-10-07 | 2013-10-11 | 118 | 516d |  | start no earlier than 2013-10-07 |
| 120 | 4.6 | **Acquisition Camera** | 136d? | 2012-10-29 | 2013-05-06 |  | 649d |  |  |
| 121 | 4.6.1 | Acquisition Camera Procurements/Fabrication | 90d? | 2012-10-29 | 2013-03-01 |  | 695d |  | start no earlier than 2012-10-29 |
| 122 | 4.6.2 | Acquisition Camera Assembly & Align | 35d? | 2013-02-11 | 2013-03-29 |  | 649d | 0d | finish no earlier than 2013-03-29 |
| 123 | 4.6.3 | Acquisition Camera Testing & Characterization | 20d? | 2013-04-01 | 2013-04-26 | 122 | 649d | 0d | start no earlier than 2013-04-01 |
| 124 | 4.6.4 | Acquisition Camera Acceptance Review | 1d? | 2013-05-06 | 2013-05-06 | 123FS+5d | 649d |  |  |

| ID | WBS | Task | Duration | Start | Finish | Predecessors | Total slack | Free slack | Constraint |
| --- | --- | --- | --- | --- | --- | --- | --- | --- | --- |
| 125 | 4.7 | **Alignment, Calibration & Diagnostics** | 191d? | 2012-10-15 | 2013-07-08 |  | 604d |  |  |
| 126 | 4.7.1 | Calibration Unit Procurements/Fabrication | 130d? | 2012-10-15 | 2013-04-12 |  | 665d |  | finish no earlier than 2013-04-12 |
| 127 | 4.7.2 | Calibration Unit Assembly & Align | 35d? | 2013-03-11 | 2013-04-26 |  | 567d | 0d | finish no earlier than 2013-04-26 |
| 128 | 4.7.3 | Calibration Unit Testing & Characterization | 45d? | 2013-04-29 | 2013-06-28 | 127 | 567d | 0d | start no earlier than 2013-04-29 |
| 129 | 4.7.4 | Calibration Unit Acceptance Review | 1d? | 2013-07-08 | 2013-07-08 | 128FS+5d | 567d | 80d |  |
| 130 | 4.8 | **Real-Time Control (RTC)** | 370d? | 2012-10-01 | 2014-02-28 |  | 435d |  |  |
| 131 | 4.8.1 | **RTC Hardware** | 135d? | 2012-10-01 | 2013-04-05 |  | 670d |  |  |
| 132 | 4.8.1.1 | RTC Hardware Procurements | 110d? | 2012-10-01 | 2013-03-01 |  | 695d |  | start no earlier than 2012-10-01 |
| 133 | 4.8.1.2 | RTC Racks Assembly | 45d? | 2013-02-04 | 2013-04-05 |  | 670d |  | finish no earlier than 2013-04-05 |
| 134 | 4.8.2 | **DM & Driver Procurements** | 150d? | 2012-10-01 | 2013-04-26 |  | 580d |  |  |
| 135 | 4.8.2.1 | LODM/TT Procurement | 150d? | 2012-10-01 | 2013-04-26 |  | 585d | 0d | finish no earlier than 2013-04-26 |
| 136 | 4.8.2.2 | HODM Procurement | 150d? | 2012-10-01 | 2013-04-26 |  | 580d | 0d | finish no earlier than 2013-04-26 |
| 137 | 4.8.2.3 | LOWFS DM Procurement | 110d? | 2012-10-01 | 2013-03-01 |  | 657d | 0d | finish no earlier than 2013-03-01 |
| 138 | 4.8.3 | **DM & Driver Testing & Acceptance** | 70d? | 2013-03-04 | 2013-06-07 |  | 620d |  |  |
| 139 | 4.8.3.1 | LODM/TT Testing & Acceptance | 30d? | 2013-04-29 | 2013-06-07 | 135 | 585d | 0d | finish no earlier than 2013-06-07 |
| 140 | 4.8.3.2 | HODM Testing & Acceptance | 30d? | 2013-04-29 | 2013-06-07 | 136 | 580d | 5d | finish no earlier than 2013-06-07 |
| 141 | 4.8.3.3 | LOWFS DM Testing & Acceptance | 30d? | 2013-03-04 | 2013-04-12 | 137 | 657d | 0d | finish no earlier than 2013-04-12 |
| 142 | 4.8.3.4 | LOWFS DM Packing & Shipping to CIT | 8d? | 2013-04-15 | 2013-04-24 | 141 | 657d |  | finish no earlier than 2013-04-24 |
| 143 | 4.8.4 | RTC Software Development | 135d? | 2012-10-01 | 2013-04-05 |  | 670d |  | start no earlier than 2012-10-01 |
| 144 | 4.8.5 | RTC Hardware & Software Development | 150d? | 2013-04-08 | 2013-11-01 |  | 455d | 0d | finish no earlier than 2013-11-01 |
| 145 | 4.8.6 | RTC Testing & Characterization | 65d? | 2013-11-04 | 2014-01-31 | 144 | 455d |  | finish no earlier than 2014-01-31 |
| 146 | 4.8.7 | RTC Documentation | 90d? | 2013-09-30 | 2014-01-31 |  | 336d | 0d | finish no earlier than 2014-01-31 |
| 147 | 4.8.8 | RTC Acceptance Review | 5d? | 2014-02-03 | 2014-02-07 | 146 | 336d | 0d | finish no earlier than 2013-12-13 |
| 148 | 4.8.9 | **RTC Packing & Shipping** | 15d? | 2014-02-10 | 2014-02-28 | 147 | 336d |  |  |
| 149 | 4.8.9.1 | RTC Packing | 4d? | 2014-02-10 | 2014-02-13 |  | 336d | 0d | finish no earlier than 2013-12-19 |
| 150 | 4.8.9.2 | RTC Shipping to WMKO | 11d? | 2014-02-14 | 2014-02-28 | 149 | 336d | 0d | finish no earlier than 2014-01-03 |

| ID | WBS | Task | Type | Duration | Start | Finish | Predecessors | Total slack | Free slack | Constraint |
| --- | --- | --- | --- | --- | --- | --- | --- | --- | --- | --- |
| 151 | 4.9 | **AO System Lab I&T** |  | 530d? | 2012-11-12 | 2014-11-21 |  | 245d |  |  |
| 152 | 4.9.1 | **AO Setup** |  | 200d? | 2012-11-12 | 2013-08-16 |  | 575d |  |  |
| 153 | 4.9.1.1 | AO Clean Room Procurements |  | 65d? | 2012-11-12 | 2013-02-08 |  | 710d |  | finish no earlier than 2013-02-08 |
| 154 | 4.9.1.2 | AO Clean Room Setup |  | 40d? | 2013-03-04 | 2013-04-26 |  | 655d |  | finish no earlier than 2013-04-26 |
| 155 | 4.9.1.3 | AO Bench Assembly & Acceptance Complete | milestone | 0d | 2013-06-28 | 2013-06-28 | 44 | 610d |  |  |
| 156 | 4.9.1.4 | AO Bench Cold Enclosure Assembly & Acceptance Complete | milestone | 0d | 2013-08-16 | 2013-08-16 | 39 | 568d | 20d |  |
| 157 | 4.9.2 | **Control System Install** |  | 150d? | 2013-05-06 | 2013-11-29 |  | 500d |  |  |
| 158 | 4.9.2.1 | Control System Rack Installation |  | 95d? | 2013-05-06 | 2013-09-13 |  | 515d | 0d | finish no earlier than 2013-09-13 |
| 159 | 4.9.2.2 | Install AO Bench Environmental Monitors & Test |  | 5d? | 2013-09-16 | 2013-09-20 | 158 | 550d |  | finish no earlier than 2013-09-20 |
| 160 | 4.9.2.3 | Control System Cabling |  | 40d? | 2013-10-07 | 2013-11-29 | 163, 158 | 500d |  | finish no earlier than 2013-11-29 |
| 161 | 4.9.3 | AO System Pre-Lab I&T Readiness Review Preparation |  | 5d? | 2013-09-16 | 2013-09-20 | 158, 156 | 548d | 0d | start no earlier than 2013-09-16 |
| 162 | 4.9.4 | **AO Opto-Mechanics Install & Align** |  | 49d? | 2013-10-01 | 2013-12-06 |  | 487d |  |  |
| 163 | 4.9.4.1 | AO Bench Component Unpacking & Checking |  | 4d? | 2013-10-01 | 2013-10-04 | 95 | 487d | 0d | start no earlier than 2013-10-01 |
| 164 | 4.9.4.2 | Rotator Install & Align |  | 4d? | 2013-10-07 | 2013-10-10 | 163 | 487d | 0d | finish no earlier than 2013-10-10 |
| 165 | 4.9.4.3 | Low Order Relay Install & Align |  | 4d? | 2013-10-11 | 2013-10-16 | 164 | 487d | 0d | start no earlier than 2013-10-11 |
| 166 | 4.9.4.4 | High Order Relay Install & Align |  | 4d? | 2013-10-17 | 2013-10-22 | 165 | 487d | 0d | start no earlier than 2013-10-17 |
| 167 | 4.9.4.5 | LGS WFS Feed Install & Align |  | 2d? | 2013-10-23 | 2013-10-24 | 166 | 487d | 0d | start no earlier than 2013-10-23 |
| 168 | 4.9.4.6 | Acquisition Camera Install & Align |  | 2d? | 2013-10-25 | 2013-10-28 | 167 | 487d | 0d | start no earlier than 2013-10-25 |
| 169 | 4.9.4.7 | Calibration Unit Install & Align |  | 4d? | 2013-10-29 | 2013-11-01 | 129, 168 | 487d | 0d | finish no earlier than 2013-11-01 |
| 170 | 4.9.4.8 | NGS WFS Install & Align |  | 3d? | 2013-11-04 | 2013-11-06 | 169, 111 | 487d | 0d | finish no earlier than 2013-11-06 |
| 171 | 4.9.4.9 | LOWFS Install & Align |  | 5d? | 2013-11-07 | 2013-11-13 | 117, 170 | 498d | 0d | finish no earlier than 2013-11-13 |
| 172 | 4.9.4.10 | LGS WFS Window Install & Align |  | 1d? | 2013-11-14 | 2013-11-14 | 171 | 498d | 1d |  |
| 173 | 4.9.4.11 | LGS WFS Install & Align |  | 8d? | 2013-11-18 | 2013-11-27 | 101, 172 | 497d | 2d | finish no earlier than 2013-11-27 |
| 174 | 4.9.4.12 | Entrance & Interferometer Window Install & Align |  | 2d? | 2013-12-02 | 2013-12-03 | 173 | 495d | 0d | finish no earlier than 2013-12-03 |
| 175 | 4.9.4.13 | AO Bench Fiducial Install & Align |  | 3d? | 2013-12-04 | 2013-12-06 | 174 | 495d |  | finish no earlier than 2013-12-06 |
| 176 | 4.9.5 | RTC Install & Cabling |  | 15d? | 2014-03-03 | 2014-03-21 | 150 | 336d | 6d | start no earlier than 2014-01-06 |
| 177 | 4.9.6 | Science Instrument Install & Align |  | 25d? | 2014-04-21 | 2014-05-23 | 19FS+15d | 375d |  | finish no earlier than 2014-04-25 |

| ID | WBS | Task | Duration | Start | Finish | Predecessors | Total slack | Free slack | Constraint |
| --- | --- | --- | --- | --- | --- | --- | --- | --- | --- |
| 178 | 4.9.7 | **Testing & Characterization - Warm** | 210d? | 2013-11-11 | 2014-08-29 |  | 171d |  |  |
| 179 | 4.9.7.1 | Motion Control Testing & Characterization | 30d? | 2013-11-11 | 2013-12-20 | 170 | 485d |  | finish no earlier than 2013-12-20 |
| 180 | 4.9.7.2 | Device Control Testing & Characterization | 30d? | 2013-11-11 | 2013-12-20 | 170 | 485d |  | finish no earlier than 2013-12-20 |
| 181 | 4.9.7.3 | RTC Testing & Characterization | 84d? | 2014-04-01 | 2014-07-25 | 176 | 330d |  | finish no earlier than 2014-07-25 |
| 182 | 4.9.7.4 | Calibration Testing & Characterization | 45d? | 2014-04-28 | 2014-06-27 | 176 | 350d |  | finish no earlier than 2014-06-27 |
| 183 | 4.9.7.5 | Performance Budget Testing & Characterization | 44d? | 2014-07-01 | 2014-08-29 |  | 305d |  | finish no earlier than 2014-08-29 |
| 184 | 4.9.7.6 | Science Operations Tools Testing | 44d? | 2014-07-01 | 2014-08-29 |  | 5d | 0d | start no earlier than 2014-07-01 |
| 185 | 4.9.8 | **Testing & Characterization - Cold** | 45d? | 2014-09-01 | 2014-10-31 |  | 5d |  |  |
| 186 | 4.9.8.1 | AO System Lab I&T Cooldown | 5d? | 2014-09-01 | 2014-09-05 | 184 | 5d | 0d | start no earlier than 2014-09-01 |
| 187 | 4.9.8.2 | Controls Testing & Characterization - Cold | 15d? | 2014-09-08 | 2014-09-26 | 186 | 5d | 0d | finish no earlier than 2014-09-26 |
| 188 | 4.9.8.3 | Alignment Testing & Characterization - Cold | 10d? | 2014-09-15 | 2014-09-26 | 186FS+5d | 285d |  | finish no earlier than 2014-09-26 |
| 189 | 4.9.8.4 | RTC Testing & Characterization - Cold | 20d? | 2014-09-29 | 2014-10-24 | 187 | 265d |  | finish no earlier than 2014-10-24 |
| 190 | 4.9.8.5 | Calibration Testing & Characterization - Cold | 20d? | 2014-09-29 | 2014-10-24 | 187 | 5d | 0d | finish no earlier than 2014-10-24 |
| 191 | 4.9.8.6 | Performance Budget Testing & Characterization - Cold | 5d? | 2014-10-27 | 2014-10-31 | 190 | 260d |  | start no earlier than 2014-10-20 |
| 192 | 4.9.8.7 | Science Operations Tools Testing - Cold | 5d? | 2014-10-27 | 2014-10-31 | 190 | 5d |  | start no earlier than 2014-10-20 |
| 193 | 4.9.9 | AO System Pre-Telescope Readiness Review Preparation | 10d? | 2014-11-10 | 2014-11-21 | 192 | 0d |  | finish no earlier than 2014-11-21 |
| 194 | 5 | **Laser Guide Star Facility** | 305d? | 2012-10-01 | 2013-11-29 | 9 | 484d |  |  |
| 195 | 5.1 | Laser Enclosure | 1d? | 2012-10-01 | 2012-10-01 |  | 804d |  |  |
| 196 | 5.2 | **Laser** | 174d? | 2012-10-01 | 2013-05-30 |  | 484d |  |  |
| 197 | 5.2.1 | Laser Unit 1 Fabrication | 61d? | 2012-10-01 | 2012-12-24 | 410 | 484d | 14d | finish no earlier than 2012-12-24 |
| 198 | 5.2.2 | Laser Unit 2 Fabrication | 174d? | 2012-10-01 | 2013-05-30 | 410 | 631d |  | finish no earlier than 2013-05-30 |
| 199 | 5.2.3 | Laser Unit 3 Fabrication | 174d? | 2012-10-01 | 2013-05-30 | 410 | 631d |  | finish no earlier than 2013-05-30 |
| 200 | 5.3 | Laser Launch Facility | 1d? | 2012-10-01 | 2012-10-01 |  | 804d |  |  |
| 201 | 5.4 | Laser Safety Systems | 1d? | 2012-10-01 | 2012-10-01 |  | 804d |  |  |

| ID | WBS | Task | Duration | Start | Finish | Predecessors | Total slack | Free slack | Constraint | Resources | Work | Text1 |
| --- | --- | --- | --- | --- | --- | --- | --- | --- | --- | --- | --- | --- |
| 202 | 5.5 | **Laser Lab I&T** | 230d? | 2013-01-14 | 2013-11-29 |  | 470d |  |  |  |  |  |
| 203 | 5.5.1 | Laser Unit 1 Lab I&T | 110d? | 2013-01-14 | 2013-06-14 | 197 | 470d | 0d | finish no earlier than 2013-06-14 |  |  |  |
| 204 | 5.5.2 | Laser Unit 2 Lab I&T | 60d? | 2013-06-17 | 2013-09-06 | 203 | 470d | 0d | finish no earlier than 2013-09-06 |  |  |  |
| 205 | 5.5.3 | Laser Unit 3 Lab I&T | 60d? | 2013-09-09 | 2013-11-29 | 204 | 470d | 0d | finish no earlier than 2013-11-29 |  |  |  |
| 206 | 6 | **Control System** | 60d? | 2012-10-01 | 2012-12-21 | 9 | 745d |  |  |  | 11240h |  |
| 207 | 6.1 | **AO Control System** | 60d? | 2012-10-01 | 2012-12-21 |  | 745d |  |  |  | 4720h |  |
| 208 | 6.1.1 | **Calibration / Simulation** | 30d | 2012-10-01 | 2012-11-09 |  | 775d |  |  |  | 600h | CALSIM |
| 209 | 6.1.1.1 | Electronics Design | 6w | 2012-10-01 | 2012-11-09 |  | 775d |  |  | EE | 240h |  |
| 210 | 6.1.1.2 | Software Design | 5w | 2012-10-01 | 2012-11-02 |  | 780d |  |  | SW MC; SW AO | 360h |  |
| 211 | 6.1.2 | **Wide Field Relay (Low Order)** | 15d | 2012-10-01 | 2012-10-19 |  | 790d |  |  |  | 280h | WFR |
| 212 | 6.1.2.1 | Electronics Design | 3w | 2012-10-01 | 2012-10-19 |  | 790d |  |  | EE | 120h |  |
| 213 | 6.1.2.2 | Software Design | 3w | 2012-10-01 | 2012-10-19 |  | 790d |  |  | SW MC; SW AO | 160h |  |
| 214 | 6.1.3 | **LGS Wavefront Sensors** | 30d | 2012-10-01 | 2012-11-09 |  | 775d |  |  |  | 640h | LGSWFS |
| 215 | 6.1.3.1 | Electronics Design | 6w | 2012-10-01 | 2012-11-09 |  | 775d |  |  | EE | 240h |  |
| 216 | 6.1.3.2 | Software Design | 6w | 2012-10-01 | 2012-11-09 |  | 775d |  |  | SW MC; SW AO | 400h |  |
| 217 | 6.1.4 | **Acquisition Camera** | 15d | 2012-10-01 | 2012-10-19 |  | 790d |  |  |  | 280h | ACQ |
| 218 | 6.1.4.1 | Electronics Design | 2w | 2012-10-01 | 2012-10-12 |  | 795d |  |  | EE | 80h |  |
| 219 | 6.1.4.2 | Software Design | 3w | 2012-10-01 | 2012-10-19 |  | 790d |  |  | SW MC; SW AO | 200h |  |
| 220 | 6.1.5 | **Low Order Wavefront Sensors** | 20d | 2012-10-01 | 2012-10-26 |  | 785d |  |  |  | 360h | LOWFS |
| 221 | 6.1.5.1 | Electronics Design | 3w | 2012-10-01 | 2012-10-19 |  | 790d |  |  | EE | 120h |  |
| 222 | 6.1.5.2 | Software Design | 4w | 2012-10-01 | 2012-10-26 |  | 785d |  |  | SW MC; SW AO | 240h |  |
| 223 | 6.1.6 | **Narrow Field Relay (High Order)** | 10d | 2012-10-01 | 2012-10-12 |  | 795d |  |  |  | 200h | NFR |
| 224 | 6.1.6.1 | Electronics Design | 2w | 2012-10-01 | 2012-10-12 |  | 795d |  |  | EE | 80h |  |
| 225 | 6.1.6.2 | Software Design | 2w | 2012-10-01 | 2012-10-12 |  | 795d |  |  | SW MC; SW AO | 120h |  |

Notes:
- 208: Hardware: / ·injection fold (linear) / ·field selector (linear) / ·source grid (4dof: 3xlinear,1xrotator) / ·source positioner (rotator) / ·laser source (linear) / ·turbulence generator (3dof: 2xrotator, 1xlinear) / Software: / ·single dof device controllers for: fold, selector, positioner, laser / ·special device controller for source grid / ·special device controller for turbulence generator / ·non-motion device controls for laser source and / ·non-motion device controls for turblence generator / ·supervisory control sequencer (~14 calibration sequences)
- 211: First optical relay of the NGAO AO system as the light leaves the telescope tertiary mirror. It contains the Low Order Deformable Mirror (LODM), various pickoff optics and optics for reimage the main telescope Nasmyth focus. This term is preferred to Low Order Relay or Woofer Relay. / PBS refers to this as: "Low Order DM & Tip-Tilt Platform" but we're going to use "Wide Field Relay" (per Chris' definition) even though we prefer "Low Order Relay". / Hardware: / ·image rotator* / ·lodm t/t (non-realtime) / ·lodm (non-realtime) / Software: / ·image rotator device control / ·lodm non-realtime controls: on/off / ·image rotator high level controller
- 214: Hardware: / ·3x object select (2dof) / ·7x tip/tilt (non-realtime) / ·3x patrolling beacon (2dof) / ·focus stage / ·details for handling pickoff arms / Software: / ·device controllers for 6x2dof devices / ·device controller for linear focus stage / ·non-realtime control for 7 t/t devices (on/off) / ·supervisory controller: moving more of the intelligence for the pickoffs to the NGAO Controls level to get the best control of positioning. also need some extra time to investigate and design spiral searches and the numerous control loops
- 217: Hardware: / ·filter wheel (rotary) / ·focus stage (linear) / Software: / ·device controller for filter wheel / ·device controller for focus stage / ·supervisory conrol sequencer
- 220: Detailed design and documentation for: / Hardware: / ·3x object select arm (2dof: rotatary) / ·3x tip/tilt non-realtime control / ·lowfs dm non-realtime control / ·3x focus stage (linear) / Software: / ·customized device controller for object select arms / ·non-motion device control (on/off) for 3x tip/tilt and 1x dm stages / ·3x device controller for linear focus stage / ·supervisory sequencer
- 223: Second optical relay of the NGAO AO system as the light leaves the telescope tertiary mirror. It follows directly after the Wide Field Relay. It contains the High Order Deformable Mirror (HODM) pickoff optics and optics for reimage the main telescope Nasmyth focus. This term is preferred to High Order Relay or Tweeter Relay. / PBS refers to this as: "High Order DM & Tip-Tilt Platform" but we're going to use "Narrow Field Relay" (per Chris' definition) even though we prefer "High Order Relay". / Hardware: / ·hodm slow tip/tilt (2dof) / ·hodm non-realtime control / Software: / ·hodm non-realtime control / ·device controller for tip/tilt / ·tip/tilt sequencer controller

| ID | WBS | Task | Duration | Start | Finish | Total slack | Resources | Work | Text1 |
| --- | --- | --- | --- | --- | --- | --- | --- | --- | --- |
| 226 | 6.1.7 | **Optical Switchyard** | 10d | 2012-10-01 | 2012-10-12 | 795d |  | 120h | AOSY |
| 227 | 6.1.7.1 | Electronics Design | 2w | 2012-10-01 | 2012-10-12 | 795d | EE | 80h |  |
| 228 | 6.1.7.2 | Software Design | 1w | 2012-10-01 | 2012-10-05 | 800d | SW MC | 40h |  |
| 229 | 6.1.8 | **NGS Wavefront Sensor** | 16d | 2012-10-01 | 2012-10-22 | 789d |  | 320h | NGSWFS |
| 230 | 6.1.8.1 | Electronics Design | 3w | 2012-10-01 | 2012-10-19 | 790d | EE | 120h |  |
| 231 | 6.1.8.2 | Software Design | 3.2w | 2012-10-01 | 2012-10-22 | 789d | SW MC [125%]; SW AO [125%] | 200h |  |
| 232 | 6.1.9 | **Atmospheric Dispersion Corrector** | 15d | 2012-10-01 | 2012-10-19 | 790d |  | 280h | ADC |
| 233 | 6.1.9.1 | Electronics Design | 2w | 2012-10-01 | 2012-10-12 | 795d | EE | 80h |  |
| 234 | 6.1.9.2 | Software Design | 3w | 2012-10-01 | 2012-10-19 | 790d | SW MC; SW AO | 200h |  |
| 235 | 6.1.10 | **AO Enclosures** | 40d | 2012-10-01 | 2012-11-23 | 765d |  | 1040h | ENC |
| 236 | 6.1.10.1 | **Electronics Design** | 40d | 2012-10-01 | 2012-11-23 | 765d |  | 800h |  |
| 237 | 6.1.10.1.1 | AO Room (inc: input and output hatches) | 5w | 2012-10-01 | 2012-11-02 | 780d | EE | 200h |  |
| 238 | 6.1.10.1.2 | AO Electronics Vault | 8w | 2012-10-01 | 2012-11-23 | 765d | EE | 320h |  |
| 239 | 6.1.10.1.3 | AO Cold Enclosure (Bench) | 7w | 2012-10-01 | 2012-11-16 | 770d | EE | 280h |  |
| 240 | 6.1.10.2 | Software Design | 6w | 2012-10-01 | 2012-11-09 | 775d | SW MC | 240h |  |
| 241 | 6.1.11 | AO Control Sequencer | 12w | 2012-10-01 | 2012-12-21 | 745d | SW AO | 480h | AOSEQ |
| 242 | 6.1.12 | RTC Interface | 10d? | 2012-10-01 | 2012-10-12 | 795d | SW | 80h |  |
| 243 | 6.1.13 | Atmospheric Profiler Interface | 5d? | 2012-10-01 | 2012-10-05 | 800d | SW | 40h |  |
| 244 | 6.2 | **LGSF Control System** | 60d? | 2012-10-01 | 2012-12-21 | 745d |  | 2120h |  |
| 245 | 6.2.1 | **Laser Controller Interface** | 15d? | 2012-10-01 | 2012-10-19 | 790d |  | 160h | LIF |
| 246 | 6.2.1.1 | Communication Cabling | 5d? | 2012-10-01 | 2012-10-05 | 800d | EE | 40h |  |
| 247 | 6.2.1.2 | Control / Status Interface | 15d? | 2012-10-01 | 2012-10-19 | 790d | SW MC | 120h |  |
| 248 | 6.2.2 | **Laser Switchyard** | 20d? | 2012-10-01 | 2012-10-26 | 785d |  | 360h | LSY |
| 249 | 6.2.2.1 | Electronics Design | 20d? | 2012-10-01 | 2012-10-26 | 785d | EE | 160h |  |
| 250 | 6.2.2.2 | Software Design | 15d? | 2012-10-01 | 2012-10-19 | 790d | SW MC; SW AO | 200h |  |

Notes:
- 226: Detailed design and documentation: / Hardware: / ·interferometer dichroic (linear) / ·acquisition fold (linear) [part of ACQ] / ·ngs wfs dichroic (linear) [part of NGSWFS] / ·instrument select (rotary) / Software: / ·3x linear device controllers / ·1x rotary device controller
- 229: Hardware: / ·2x wfs fsm (2dof: tip/tilt) / ·wfs lenslet (2dof: linear) / ·focus stage (linear) / ·collision avoidance mechanism between lenslet and focus stage / Software: / ·2dof device controllers for fsms and lenslet / ·device controller for focus stage / ·supervisory controller: there will have to be some serious thought about how to coordinate offloading / tip-tilt correction between TTM2 and FSMs. Based on Eds comment about focus and lenslet stage collision it seems like the supervisory controller will have to be more intelligent than I originally assumed.
- 232: Detailed design and documenation base on assumptions of what it is / Hardware: / ·adc (2dof: either rotary or linear) / ·linear stage / Software: / ·2dof device controller (custom?) / ·linear stage device controller / ·high level controller (actively controlling positions)
- 237: Large room on the Keck Telescope Nasmyth platform containing the AO system, for NGAO it will be climate controlled. Temperature will be ~dome ambient, nominally 0 degrees Celsius +/- 10 degrees. / ·room temperature / ·humidity / ·dust / ·rack/equipment temperatures / ·camera / ·A/C controls / ·HEPA controls / ·lights controls / ·input hatch* / ·interferometer output hatch*
- 238: Large room containing electronics that support operation of the AO system. Room is keep at a warmer temperature than the AO Room, ~17 degrees Celsius (63 degrees Fahrenheit). Waste heat is removed by a cooling system. The Electronics Vault must be thermally isolated to some degree from adjoining AO Room. Frequently abbreviated e-vault. / ·glycol flow / ·temperature / ·ca/sim source output / ·cal/sim source power / ·cal/sim source intensity readback / ·motion control local/remote / ·motion control status / ·ac controls / ·racks / ·cabling
- 239: Smaller enclosure that surrounds the AO system bench and is cooled to approximately -15 degree Celsius to reduce emissivity (background) for infrared wavelength observations. (Note that the exact temperature of the AO Cold Enclosure is subject to change as design progresses). Previously referred to as the cold box. / ·temperature / ·humidity / ·dust / ·video camera / ·accels / ·IF IBM-T source / ·lights control / ·racks / ·cabling
- 240: Software: / ·readback for: / ·temperature/ ·humidity/ ·dust/ ·cal/sim source intensity / ·control and readback for: / ·accels/ ·AC/ ·HEPA/ ·lights/ ·motion control/ ·cal/sim source / ·surveillance camera controls
- 241: High level AO control sequencer. / Interfaces to higher level operations level controllers and coordinates and controls lower level AO device controllers accordingly. Lots of sequences need to be understood and developed.
- 245: Detailed design and documentation for interfacing to the vendor supplied laser controller. / Will be reading statuses and sending commands to laser controller. No automated control loops are envisioned at this time.
- 248: Hardware: / ·3x polarizing 1/4 waveplate (1dof: rotary) / ·3x polarizing 1/2 waveplate (1dof: rotary) / ·3x pointing/steering mirrors (2dof: tip/tilt) / ·alignment beamsplitter (1dof: linear) / Software: / ·6x device controllers for rotary devices / ·3x 2dof device controllers for pointing/steering mirrors / ·linear device controller / ·supervisory sequencer

| ID | WBS | Task | Duration | Start | Finish | Total slack | Resources | Work | Text1 |
| --- | --- | --- | --- | --- | --- | --- | --- | --- | --- |
| 251 | 6.2.3 | **Laser Beam Generation System** | 35d? | 2012-10-01 | 2012-11-16 | 770d |  | 680h | BGS |
| 252 | 6.2.3.1 | Electronics Design | 30d? | 2012-10-01 | 2012-11-09 | 775d | EE | 240h |  |
| 253 | 6.2.3.2 | Software Design | 35d? | 2012-10-01 | 2012-11-16 | 770d | SW MC; SW AO | 440h |  |
| 254 | 6.2.4 | **Laser Safety System** | 15d? | 2012-10-01 | 2012-10-19 | 790d |  | 240h | LSS |
| 255 | 6.2.4.1 | Electronics Design | 1d? | 2012-10-01 | 2012-10-01 | 804d |  |  |  |
| 256 | 6.2.4.2 | **Software Design** | 15d? | 2012-10-01 | 2012-10-19 | 790d |  | 240h |  |
| 257 | 6.2.4.2.1 | Safety System Interface | 15d? | 2012-10-01 | 2012-10-19 | 790d | SW MC | 120h |  |
| 258 | 6.2.4.2.2 | LTCS | 10d? | 2012-10-01 | 2012-10-12 | 795d | SW AO | 80h |  |
| 259 | 6.2.4.2.3 | Laser Clearinghouse | 5d? | 2012-10-01 | 2012-10-05 | 800d | SW AO | 40h |  |
| 260 | 6.2.5 | **Laser Service Enclosure** | 15d? | 2012-10-01 | 2012-10-19 | 790d |  | 200h | LSE |
| 261 | 6.2.5.1 | Electronics Design | 15d? | 2012-10-01 | 2012-10-19 | 790d | EE | 120h |  |
| 262 | 6.2.5.2 | Software Design | 10d? | 2012-10-01 | 2012-10-12 | 795d | SW MC | 80h |  |
| 263 | 6.2.6 | Laser Beam Transport Optics | 1d? | 2012-10-01 | 2012-10-01 | 804d |  |  |  |
| 264 | 6.2.7 | Laser Control Sequencer | 60d? | 2012-10-01 | 2012-12-21 | 745d | SW AO | 480h |  |
| 265 | 6.3 | **Control System Infrastructure** | 60d? | 2012-10-01 | 2012-12-21 | 745d |  | 4400h |  |
| 266 | 6.3.1 | **Motion Control** | 60d? | 2012-10-01 | 2012-12-21 | 745d |  | 960h |  |
| 267 | 6.3.1.1 | Electronics | 60d? | 2012-10-01 | 2012-12-21 | 745d | EE | 480h |  |
| 268 | 6.3.1.2 | Software | 60d? | 2012-10-01 | 2012-12-21 | 745d | SW MC | 480h |  |
| 269 | 6.3.2 | **Device Control** | 60d? | 2012-10-01 | 2012-12-21 | 745d |  | 960h |  |
| 270 | 6.3.2.1 | Electronics | 60d? | 2012-10-01 | 2012-12-21 | 745d | EE | 480h |  |
| 271 | 6.3.2.2 | Software | 60d? | 2012-10-01 | 2012-12-21 | 745d | SW MC | 480h |  |
| 272 | 6.3.3 | **Monitoring** | 1d? | 2012-10-01 | 2012-10-01 | 804d |  |  | MON |
| 273 | 6.3.3.1 | Vibration | 1d? | 2012-10-01 | 2012-10-01 | 804d |  |  |  |
| 274 | 6.3.3.2 | Temperature | 1d? | 2012-10-01 | 2012-10-01 | 804d |  |  |  |
| 275 | 6.3.3.3 | Humidity | 1d? | 2012-10-01 | 2012-10-01 | 804d |  |  |  |
| 276 | 6.3.3.4 | Dust | 1d? | 2012-10-01 | 2012-10-01 | 804d |  |  |  |

Notes:
- 251: Hardware: / ·2x beam splitter (1dof: linear) / ·imager pickoff (1dof: linear) / ·3x patrolling lgs steering (2dof: linear) / ·asterism rotator (1dof: rotary) / ·asterism tip/tilt (2dof: tipt/tilt) / ·fast shutter / ·focus stage (1dof: linear) / ·lto polarization sensor (2dof: rotary) / ·lto cover (1dof: ?) / ·beam wfs / ·power / ·polarization sensor / ·beam position sensor / ·AC controls / ·temperature / ·humidity / Software: / ·5x 1dof linear device controllers / ·3x 2dof linear device controllers / ·1dof rotary device controller / ·2dof rotary device controller / ·2dof tip/tilt device controller / ·shutter type device control / ·non-motion device status and control / ·high level control sequencer (5wks)
- 255: Don't think there's anything here for Ed to do... I'm assuming Jason will be responsible for installing and making this work under his WBS.
- 257: Detailed design and documenation for interfacing to laser safety system.
- 258: per JC: Need to make existing code work with 7beams and transfer to new system, see: / http://www.oir.caltech.edu/twiki_oir/pub/Keck/NGAO/LaserPDRPhase/NGAO_LTCS_Modification_Preliiminary_Design_DS.doc / DSummers estimate: DD 32hrs, FSD 100hrs / reference documents: / http://keckshare.keck.hawaii.edu/dsweb/Get/Document-35985/KAON713.doc/ http://keckshare.keck.hawaii.edu/dsweb/Get/Document-7474/SDF_KECK_LTCS_URLs.doc/ http://keckshare.keck.hawaii.edu/dsweb/Get/Document-7472/SDF_revised_draft.doc
- 259: per JC: Transfer existing tool to new system, see: http://www.oir.caltech.edu/twiki_oir/pub/Keck/NGAO/LaserPDRPhase/NGAO_Laser_Clearing_House_Planning.doc
- 260: Hardware: / ·beam dump / ·temperature / ·humidity / ·dust / ·video camera / ·AC controls / Software: / ·non-motion device status and controls
- 263: This is being handled by the MRI proposal and JC has it covered.
- 264: Detailed design and documentation for high level laser control sequencer. / Interfaces to higher level operations level controllers and coordinates and controls lower level laser device controllers accordingly.
- 266: Motion device control. / Hardware: / ·platform selection / ·motion controller selection / ·motion controller locations / ·amplifiers / ·wiring / ·etc... / Software: / ·software interface / · low level device controller / ·device control state machine / · low level engineering gui interface
- 269: Non-motion device control. / Hardware: / ·controller selection / ·temperature / ·humidity / ·dust/ ·wiring / ·video camera / ·power / ·etc... / Software: / ·device drivers for each type / ·interface definition / ·attribute definitions / ·method definition / ·etc...
- 272: The bulk of this would be done under "Device Control" for hardware selection and software driver stuff. With the actual monitoring falling uder the various enclosures.

| ID | WBS | Task | Duration | Start | Finish | Predecessors | Total slack | Resources | Work | Text1 |
| --- | --- | --- | --- | --- | --- | --- | --- | --- | --- | --- |
| 277 | 6.3.4 | **Electronics** | 15d? | 2012-10-01 | 2012-10-19 |  | 790d |  | 360h |  |
| 278 | 6.3.4.1 | Instrument Interface | 5d? | 2012-10-01 | 2012-10-05 |  | 800d | EE | 40h |  |
| 279 | 6.3.4.2 | Interferometer Interface | 5d? | 2012-10-01 | 2012-10-05 |  | 800d | EE | 40h |  |
| 280 | 6.3.4.3 | Control Computers | 5d? | 2012-10-01 | 2012-10-05 |  | 800d | EE | 40h |  |
| 281 | 6.3.4.4 | Realtime Control Computers | 10d? | 2012-10-01 | 2012-10-12 |  | 795d | EE | 80h |  |
| 282 | 6.3.4.5 | Time Infrastructure (Sync) | 15d? | 2012-10-01 | 2012-10-19 |  | 790d | EE | 120h |  |
| 283 | 6.3.4.6 | Communication Infrastructure | 5d? | 2012-10-01 | 2012-10-05 |  | 800d | EE | 40h |  |
| 284 | 6.3.5 | **Software** | 60d? | 2012-10-01 | 2012-12-21 |  | 745d |  | 1560h | INFR |
| 285 | 6.3.5.1 | Revisit KCSF vs EPICS decision | 40d? | 2012-10-01 | 2012-11-23 |  | 765d | SW | 320h |  |
| 286 | 6.3.5.2 | Health Monitoring | 10d? | 2012-10-01 | 2012-10-12 |  | 795d | SW | 80h |  |
| 287 | 6.3.5.3 | Logging | 10d? | 2012-10-01 | 2012-10-12 |  | 795d | SW | 80h |  |
| 288 | 6.3.5.4 | Archiving | 10d? | 2012-10-01 | 2012-10-12 |  | 795d | SW | 80h |  |
| 289 | 6.3.5.5 | Alarming | 15d? | 2012-10-01 | 2012-10-19 |  | 790d | SW | 120h |  |
| 290 | 6.3.5.6 | Configuration | 30d? | 2012-10-01 | 2012-11-09 |  | 775d | SW | 240h |  |
| 291 | 6.3.5.7 | Keyword Interface | 10d? | 2012-10-01 | 2012-10-12 |  | 795d | SW | 80h |  |
| 292 | 6.3.5.8 | EPICS Channel Access Interface | 10d? | 2012-10-01 | 2012-10-12 |  | 795d | SW | 80h |  |
| 293 | 6.3.5.9 | Utility Scripts | 60d? | 2012-10-01 | 2012-12-21 |  | 745d | SW | 480h |  |
| 294 | 6.3.6 | **Data Server** | 60d? | 2012-10-01 | 2012-12-21 |  | 745d |  | 560h | DS |
| 295 | 6.3.6.1 | Software Design | 60d? | 2012-10-01 | 2012-12-21 |  | 745d | SW | 480h |  |
| 296 | 6.3.6.2 | Hardware Selection | 10d? | 2012-10-01 | 2012-10-12 |  | 795d | SW | 80h |  |
| 297 | 7 | **Science Operations Tools** | 1d? | 2012-10-01 | 2012-10-01 | 9 | 804d |  |  |  |
| 298 | 7.1 | Multi-Systems Command Sequencer | 1d? | 2012-10-01 | 2012-10-01 |  | 804d |  |  |  |
| 299 | 7.2 | User Interfaces | 1d? | 2012-10-01 | 2012-10-01 |  | 804d |  |  |  |
| 300 | 7.3 | Pre- & Post-Observing Science Support Tools | 1d? | 2012-10-01 | 2012-10-01 |  | 804d |  |  |  |

Notes:
- 290: ·config Server / ·database design / ·config snapshot / ·gui
- 293: Library of common functions / tasks for observers, SA, developers, etc... / Still needs to be defined but I stuck a number in for now.
- 294: Detailed design and documentation including recommended computer/disk hardware selection. / Computers: 1wk / Software: 12wks / ·database definition and design / ·log files definition and design / ·interface tool specs and design / ·inter-process comm spec and design

| ID | WBS | Task | Duration | Start | Finish | Predecessors | Total slack | Free slack | Constraint |
| --- | --- | --- | --- | --- | --- | --- | --- | --- | --- |
| 301 | 8 | **Telescope & Summit Engineering** | 165d? | 2012-10-01 | 2013-05-17 | 9 | 640d |  |  |
| 302 | 8.1 | **Infrastructure Modifications for AO - part I** | 35d? | 2012-10-01 | 2012-11-16 |  | 770d |  |  |
| 303 | 8.1.1 | Prepare Old AO Packing Materials/Crates | 35d? | 2012-10-01 | 2012-11-16 |  | 770d |  | start no earlier than 2012-07-30 |
| 304 | 8.1.2 | Prepare Keck I AO for NIRC2 | 1d? | 2012-10-01 | 2012-10-01 |  | 804d |  |  |
| 305 | 8.2 | Infastructure Modifications for Laser - part I | 145d? | 2012-10-29 | 2013-05-17 |  | 640d |  | finish no earlier than 2013-05-17 |
| 306 | 8.3 | Infrastructure Modifications for Instruments - part I | 1d? | 2012-10-01 | 2012-10-01 |  | 804d |  |  |
| 307 | 8.4 | **Interferometer Modifications** | 110d? | 2012-10-01 | 2013-03-01 |  | 695d |  |  |
| 308 | 8.4.1 | Procure/Fabricate Matching Windows for Keck I AO | 85d? | 2012-11-05 | 2013-03-01 |  | 695d |  | finish no earlier than 2013-03-01 |
| 309 | 8.4.2 | Install Interferometer Hatch Covers | 1d? | 2012-10-01 | 2012-10-01 |  | 804d |  |  |
| 310 | 9 | **Telescope Integration & Test** | 690d? | 2013-03-11 | 2015-10-30 | 9 | 0d |  |  |
| 311 | 9.1 | **Remove Old AO System** | 44d? | 2014-12-01 | 2015-01-29 | 20FS+2d | 0d |  |  |
| 312 | 9.1.1 | **NIRC2 Commissioning with Keck I AO** | 44d? | 2014-12-01 | 2015-01-29 |  | 196d |  |  |
| 313 | 9.1.1.1 | Warm NIRC2 | 5d? | 2014-12-01 | 2014-12-05 |  | 235d |  | finish no earlier than 2012-10-07 |
| 314 | 9.1.1.2 | Remove NIRC2 Electronics | 4d? | 2014-12-01 | 2014-12-04 |  | 196d | 0d | finish no earlier than 2012-10-05 |
| 315 | 9.1.1.3 | Install Safety Constraints in NIRC2 for Move | 1d? | 2014-12-05 | 2014-12-05 | 314 | 196d | 0d |  |
| 316 | 9.1.1.4 | Remove NIRC2 Crane (portion over roof) | 1d? | 2014-12-08 | 2014-12-08 | 315 | 196d | 0d |  |
| 317 | 9.1.1.5 | Remove NIRC2 | 1d? | 2014-12-09 | 2014-12-09 | 316 | 196d | 0d |  |
| 318 | 9.1.1.6 | Install NIRC2 in Keck I AO | 1d? | 2014-12-10 | 2014-12-10 | 317 | 196d | 0d |  |
| 319 | 9.1.1.7 | Get NIRC2 operational with Keck I AO | 36d? | 2014-12-11 | 2015-01-29 | 318 | 196d |  | finish no earlier than 2012-11-30 |
| 320 | 9.1.2 | Move Interferometer Module out of AO | 1d? | 2014-12-01 | 2014-12-01 |  | 239d |  |  |
| 321 | 9.1.3 | Remove & Pack AO Bench Components | 5d? | 2014-12-01 | 2014-12-05 |  | 235d |  | start no earlier than 2012-10-02 |
| 322 | 9.1.4 | Remove & Pack Electronics Racks | 5d? | 2014-12-01 | 2014-12-05 |  | 235d |  | finish no earlier than 2012-10-08 |
| 323 | 9.1.5 | Remove & Reinstall Enclosure Roof | 1d? | 2014-12-08 | 2014-12-08 | 315 | 234d |  | start no earlier than 2012-10-10 |
| 324 | 9.1.6 | Remove AO Bench & Supports | 1d? | 2014-12-01 | 2014-12-01 |  | 0d |  | start no earlier than 2012-10-10 |
| 325 | 9.1.7 | Remove & Pack Electronics Cables & Boxes | 3d? | 2014-12-02 | 2014-12-04 | 324 | 0d |  | finish no earlier than 2012-10-15 |
| 326 | 9.1.8 | Remove Extraneous Azimuth Wrap Cabling | 5d? | 2014-12-01 | 2014-12-05 |  | 235d |  | finish no earlier than 2012-10-26 |
| 327 | 9.1.9 | Put Appropriate Components in Spares Inventory | 15d? | 2014-12-01 | 2014-12-19 |  | 225d |  | finish no earlier than 2012-11-09 |
| 328 | 9.1.10 | Dispose or Store Removed Equipment | 30d? | 2014-12-01 | 2015-01-09 |  | 210d |  | finish no earlier than 2012-11-30 |

| ID | WBS | Task | Duration | Start | Finish | Predecessors | Total slack | Free slack | Constraint |
| --- | --- | --- | --- | --- | --- | --- | --- | --- | --- |
| 329 | 9.2 | **Remove Old Laser System** | 185d? | 2013-03-11 | 2013-11-22 |  | 505d |  |  |
| 330 | 9.2.1 | Prepare Old Laser Table Packing Materials/Crates | 50d? | 2013-03-11 | 2013-05-17 |  | 640d |  | start no earlier than 2013-03-11 |
| 331 | 9.2.2 | Drain Preamp & Amp Dye Laser Loops | 3d? | 2013-06-17 | 2013-06-19 | 21 | 503d | 0d | start no earlier than 2013-06-17 |
| 332 | 9.2.3 | Remove & Pack Elevation Ring Electronics | 3d? | 2013-06-17 | 2013-06-19 |  | 617d |  | finish no earlier than 2013-06-19 |
| 333 | 9.2.4 | Remove & Pack Elevation Ring Laser Table | 2d? | 2013-06-20 | 2013-06-21 | 331 | 503d | 2d | start no earlier than 2013-06-20 |
| 334 | 9.2.5 | Remove Extraneous Laser Elevation Wrap Cabling | 3d? | 2013-06-24 | 2013-06-26 |  | 612d |  | finish no earlier than 2013-06-26 |
| 335 | 9.2.6 | Remove Extraneous Laser Azimuth Wrap Cabling | 3d? | 2013-06-26 | 2013-06-28 |  | 610d |  | finish no earlier than 2013-06-28 |
| 336 | 9.2.7 | Drain DMO Dye Loop | 5d? | 2013-09-30 | 2013-10-04 | 381FS+20d | 505d | 0d | finish no earlier than 2013-10-04 |
| 337 | 9.2.8 | Prepare Old Laser Room Packing Materials/Crates | 40d? | 2013-08-05 | 2013-09-27 | 381 | 545d |  | finish no earlier than 2013-09-27 |
| 338 | 9.2.9 | Remove DMO Dye Line & Cabinet | 4d? | 2013-10-07 | 2013-10-10 | 336 | 536d |  | start no earlier than 2013-10-07 |
| 339 | 9.2.10 | Remove & Pack Laser Dome Floor Hardware | 15d? | 2013-10-07 | 2013-10-25 | 336 | 510d | 0d | start no earlier than 2013-10-07 |
| 340 | 9.2.11 | Remove & Pack Laser Dome Floor Enclosure | 10d? | 2013-10-28 | 2013-11-08 | 339 | 515d |  | start no earlier than 2013-10-28 |
| 341 | 9.2.12 | Remove Cabling/Piping to Laser Dome Floor Enclosure | 15d? | 2013-10-28 | 2013-11-15 | 339 | 510d |  | start no earlier than 2013-10-28 |
| 342 | 9.2.13 | Put Appropriate Components in Spares Inventory | 20d? | 2013-10-07 | 2013-11-01 | 336 | 520d |  | start no earlier than 2013-10-07 |
| 343 | 9.2.14 | Dispose or Store Removed Equipment | 35d? | 2013-10-07 | 2013-11-22 | 336 | 505d |  | start no earlier than 2013-10-07 |
| 344 | 9.3 | **AO System Install** | 44d? | 2014-12-05 | 2015-02-04 |  | 0d |  |  |
| 345 | 9.3.1 | **Infrastructure Mods for AO - part II** | 10d? | 2014-12-05 | 2014-12-18 | 325 | 0d |  |  |
| 346 | 9.3.1.1 | Complete Enclosure Vault Modifications | 9d? | 2014-12-05 | 2014-12-17 |  | 0d |  | finish no earlier than 2012-10-26 |
| 347 | 9.3.1.2 | **Install Support Structures** | 5d? | 2014-12-05 | 2014-12-11 | 325 | 4d |  |  |
| 348 | 9.3.1.2.1 | Install AO Bench & Cold Enclosure Support | 4d? | 2014-12-05 | 2014-12-10 |  | 5d |  | finish no earlier than 2012-10-19 |
| 349 | 9.3.1.2.2 | Install Electronics Supports | 4d? | 2014-12-05 | 2014-12-10 |  | 5d | 0d | finish no earlier than 2012-10-19 |
| 350 | 9.3.1.2.3 | Install Science Instrument Support | 5d? | 2014-12-05 | 2014-12-11 |  | 4d |  | start no earlier than 2012-10-22 |
| 351 | 9.3.1.2.4 | Install LGS WFS Support | 5d? | 2014-12-05 | 2014-12-11 |  | 4d |  | start no earlier than 2012-10-22 |
| 352 | 9.3.1.2.5 | Install Interferometer Module Support | 5d? | 2014-12-05 | 2014-12-11 |  | 4d |  | start no earlier than 2012-10-22 |
| 353 | 9.3.1.3 | Clean Electronics Vault | 1d? | 2014-12-11 | 2014-12-11 | 349 | 226d | 0d |  |
| 354 | 9.3.1.4 | Clean AO Room | 1d? | 2014-12-18 | 2014-12-18 | 347, 346 | 0d |  | finish no earlier than 2012-10-29 |
| 355 | 9.3.2 | Install AO Electronics | 5d? | 2014-12-12 | 2014-12-18 | 353 | 226d |  | start no earlier than 2012-10-23 |
| 356 | 9.3.3 | Install AO Bench & Align to Telescope | 4d? | 2014-12-19 | 2014-12-24 | 354 | 0d |  | start no earlier than 2012-10-30 |
| 357 | 9.3.4 | Connect AO Bench Electronics | 2d? | 2014-12-25 | 2014-12-26 | 356 | 0d |  | start no earlier than 2014-10-23 |
| 358 | 9.3.5 | Verify AO Bench Motion & Device Control | 5d? | 2014-12-29 | 2015-01-02 | 357 | 0d |  | start no earlier than 2014-10-27 |
| 359 | 9.3.6 | Verify AO Bench Internal Alignments (+Adjust if Needed) | 5d? | 2015-01-05 | 2015-01-09 | 358 | 0d |  | start no earlier than 2014-11-03 |
| 360 | 9.3.7 | Install LGS WFS | 2d? | 2015-01-12 | 2015-01-13 | 359 | 208d |  | start no earlier than 2014-11-10 |
| 361 | 9.3.8 | Install Science Instrument | 2d? | 2015-01-12 | 2015-01-13 | 359 | 0d |  | start no earlier than 2014-11-10 |
| 362 | 9.3.9 | Clean AO Room | 1d? | 2015-01-14 | 2015-01-14 | 361 | 0d |  |  |
| 363 | 9.3.10 | Connect Science Instrument Electronics | 1d? | 2015-01-15 | 2015-01-15 | 362 | 0d |  |  |
| 364 | 9.3.11 | Cooldown Science Instrument | 9d? | 2015-01-16 | 2015-01-28 | 363 | 0d |  | finish no earlier than 2014-11-26 |
| 365 | 9.3.12 | Connect LGS WFS Electronics | 2d? | 2015-01-16 | 2015-01-19 | 363 | 199d | 0d | start no earlier than 2014-11-14 |
| 366 | 9.3.13 | Verify LGS WFS Motion & Device Control | 2d? | 2015-01-20 | 2015-01-21 | 365 | 199d | 0d | start no earlier than 2014-11-18 |
| 367 | 9.3.14 | Align LGS WFS | 3d? | 2015-01-22 | 2015-01-26 | 366 | 199d |  | finish no earlier than 2014-11-24 |
| 368 | 9.3.15 | Verify Science Instrument Motion & Device Control | 2d? | 2015-01-29 | 2015-01-30 | 364 | 0d |  | start no earlier than 2014-11-27 |
| 369 | 9.3.16 | Align Science Instrument | 3d? | 2015-02-02 | 2015-02-04 | 368 | 0d |  | start no earlier than 2014-12-01 |
| 370 | 9.3.17 | Install Interferometer Module & Align | 10d? | 2014-12-08 | 2014-12-19 |  | 225d |  | start no earlier than 2014-12-08 |
| 371 | 9.3.18 | Install/Align Matching Interferometer Windows for Keck I AO | 10d? | 2014-12-08 | 2014-12-19 |  | 225d |  | finish no earlier than 2014-12-19 |

| ID | WBS | Task | Duration | Start | Finish | Predecessors | Total slack | Free slack | Constraint |
| --- | --- | --- | --- | --- | --- | --- | --- | --- | --- |
| 372 | 9.4 | **Laser System Install** | 118d? | 2013-06-26 | 2013-12-06 |  | 495d |  |  |
| 373 | 9.4.1 | Install Support Structures | 1d? | 2013-06-26 | 2013-06-26 | 333 | 501d | 0d | finish no earlier than 2013-06-26 |
| 374 | 9.4.2 | Install Laser Unit 1 - Electronics | 5d? | 2013-06-27 | 2013-07-03 | 203 | 607d |  | finish no earlier than 2013-07-03 |
| 375 | 9.4.3 | Install Laser Unit 1 - Laser | 5d? | 2013-06-27 | 2013-07-03 | 373 | 501d | 0d | start no earlier than 2013-06-27 |
| 376 | 9.4.4 | Install Laser Switchyard | 4d? | 2013-07-04 | 2013-07-09 |  | 603d |  | finish no earlier than 2013-07-09 |
| 377 | 9.4.5 | Install Laser Unit 2 | 5d? | 2013-12-02 | 2013-12-06 | 205 | 470d | 0d | start no earlier than 2013-12-02 |
| 378 | 9.4.6 | Install Laser Unit 3 | 5d? | 2013-12-02 | 2013-12-06 | 205 | 470d | 0d | start no earlier than 2013-12-02 |
| 379 | 9.5 | AO System I&T | 82d? | 2015-02-05 | 2015-05-29 | 369 | 0d |  | start no earlier than 2015-02-05 |
| 380 | 9.6 | **Laser System I&T** | 137d? | 2013-07-04 | 2014-01-10 |  | 470d |  |  |
| 381 | 9.6.1 | Laser Unit 1 I&T | 21d? | 2013-07-04 | 2013-08-01 | 375 | 501d | 1d | start no earlier than 2013-07-04 |
| 382 | 9.6.2 | Laser Unit 1 on-sky I&T with Keck II AO | 40d? | 2013-08-05 | 2013-09-27 | 381 | 545d |  | start no earlier than 2013-08-05 |
| 383 | 9.6.3 | Laser Unit 1 Performance Characterization with Keck II AO | 85d? | 2013-08-05 | 2013-11-29 | 381 | 500d |  | finish no earlier than 2013-11-29 |
| 384 | 9.6.4 | Laser Unit 2 I&T | 25d? | 2013-12-09 | 2014-01-10 | 377 | 470d |  | finish no earlier than 2014-01-10 |
| 385 | 9.6.5 | Laser Unit 3 I&T | 25d? | 2013-12-09 | 2014-01-10 | 378 | 470d |  | start no earlier than 2013-12-09 |
| 386 | 9.7 | LGS AO System On-sky I&T | 85d? | 2015-06-01 | 2015-09-25 | 379 | 25d | 0d | finish no earlier than 2015-09-25 |
| 387 | 9.8 | Performance Characterization | 90d? | 2015-06-29 | 2015-10-30 | 379FS+20d | 0d |  | finish no earlier than 2015-10-30 |
| 388 | 9.9 | Science Verification | 70d? | 2015-07-27 | 2015-10-30 | 379FS+40d | 0d |  | start no earlier than 2015-07-27 |
| 389 | 10 | **Operations Transition** | 1d? | 2012-10-01 | 2012-10-01 | 9 | 804d |  |  |
| 390 | 10.1 | **Operations Plans** | 1d? | 2012-10-01 | 2012-10-01 |  | 804d |  |  |
| 391 | 10.1.1 | AO Operations Plans Revision - Pre-Telescope I&T | 1d? | 2012-10-01 | 2012-10-01 |  | 804d |  |  |
| 392 | 10.1.2 | LGSF Operations Plans Revision - Post-Telescope I&T | 1d? | 2012-10-01 | 2012-10-01 |  | 804d |  |  |
| 393 | 10.1.3 | AO Operations Plans Revision - Post-Telescope I&T | 1d? | 2012-10-01 | 2012-10-01 |  | 804d |  |  |
| 394 | 10.2 | **Operations Handover** | 1d? | 2012-10-01 | 2012-10-01 |  | 804d |  |  |
| 395 | 10.2.1 | LGSF Lab Training | 1d? | 2012-10-01 | 2012-10-01 |  | 804d |  |  |
| 396 | 10.2.2 | LGSF Training | 1d? | 2012-10-01 | 2012-10-01 |  | 804d |  |  |
| 397 | 10.2.3 | AO Lab Training | 1d? | 2012-10-01 | 2012-10-01 |  | 804d |  |  |
| 398 | 10.2.4 | AO Facility Training | 1d? | 2012-10-01 | 2012-10-01 |  | 804d |  |  |

| ID | WBS | Task | Type | Duration | Start | Finish | Predecessors | Total slack | Free slack | Constraint |
| --- | --- | --- | --- | --- | --- | --- | --- | --- | --- | --- |
| 399 | 11 | **Related Activities** |  | 1095d? | 2010-03-22 | 2014-06-02 |  | 370d |  |  |
| 400 | 11.1 | **K2 Launch Telescope (MRI-funded)** |  | 296d? | 2010-07-21 | 2011-09-07 |  | 1082d |  |  |
| 401 | 11.1.1 | LT Preliminary Design Review | milestone | 0d | 2010-07-21 | 2010-07-21 |  | 1378d |  | start no earlier than 2010-07-21 |
| 402 | 11.1.2 | LT Detailed Design | milestone | 0d | 2010-10-29 | 2010-10-29 |  | 1306d |  | start no earlier than 2010-10-29 |
| 403 | 11.1.3 | LT Delivery | milestone | 0d | 2011-01-07 | 2011-01-07 |  | 1256d |  | start no earlier than 2011-01-07 |
| 404 | 11.1.4 | LT Telescope I&T |  | 68d? | 2011-04-04 | 2011-07-06 |  | 1082d | 0d | finish no earlier than 2011-07-06 |
| 405 | 11.1.5 | LT Commissioning |  | 45d? | 2011-07-07 | 2011-09-07 | 404 | 1082d |  | finish no earlier than 2011-09-07 |
| 406 | 11.2 | **TOPTICA Laser (ESO-funded)** |  | 720d | 2010-03-22 | 2012-12-24 |  | 745d |  |  |
| 407 | 11.2.1 | M1: Kick-off Meeting | milestone | 0d | 2010-03-22 | 2010-03-22 |  | 1144d | 261d | start no earlier than 2010-03-22 |
| 408 | 11.2.2 | M2: Laser Final Design Review | milestone | 0d | 2011-03-22 | 2011-03-22 | 407 | 883d | 132d | start no earlier than 2011-03-22 |
| 409 | 11.2.3 | M3: Pre-Production Unit Completion | milestone | 0d | 2011-09-22 | 2011-09-22 | 408 | 751d | 130d | start no earlier than 2011-09-22 |
| 410 | 11.2.4 | M4: Laser Unit 1 Factory Readiness Test | milestone | 0d | 2012-03-22 | 2012-03-22 | 409 | 621d | 137d | start no earlier than 2012-03-22 |
| 411 | 11.2.5 | M6: Remaining Laser Factory Readiness Tests | milestone | 0d | 2012-12-24 | 2012-12-24 | 410 | 745d |  | start no earlier than 2012-12-24 |
| 412 | 11.3 | **New K2 Laser (MRI proposal)** |  | 956d | 2010-10-01 | 2014-06-02 |  | 370d |  |  |
| 413 | 11.3.1 | K2 Laser Project Start | milestone | 0d | 2010-10-01 | 2010-10-01 |  | 1326d |  | start no earlier than 2010-10-01 |
| 414 | 11.3.2 | K2 Laser Detailed Design Review | milestone | 0d | 2012-05-01 | 2012-05-01 |  | 914d |  | start no earlier than 2012-05-01 |
| 415 | 11.3.3 | K2 Laser Arrival at WMKO HQ | milestone | 0d | 2013-04-16 | 2013-04-16 | 410 | 664d |  | start no earlier than 2013-04-16 |
| 416 | 11.3.4 | K2 Laser Pre-Telescope Readiness Review | milestone | 0d | 2013-07-03 | 2013-07-03 |  | 608d |  | start no earlier than 2013-07-03 |
| 417 | 11.3.5 | Existing K2 Laser Goes Off-Line | milestone | 0d | 2013-11-01 | 2013-11-01 |  | 521d |  | start no earlier than 2013-11-01 |
| 418 | 11.3.6 | K2 Laser First Light | milestone | 0d | 2014-01-07 | 2014-01-07 |  | 474d |  | start no earlier than 2014-01-07 |
| 419 | 11.3.7 | K2 Laser Operational Readiness Review | milestone | 0d | 2014-06-02 | 2014-06-02 |  | 370d |  | start no earlier than 2014-06-02 |
